# DIAGRAMA GANTT PAJARITOS

Schedule from MS Project, 2023-01-02 to 2023-06-30, costs in S..

## Calendars

- Estándar: Mon-Sat 08:00-13:00, 14:00-17:00; Sun off.

## Schedule

| ID | WBS | Task | Type | Duration | Start | Finish | Predecessors | Total slack | Free slack | Cost | Text1 |
| --- | --- | --- | --- | --- | --- | --- | --- | --- | --- | --- | --- |
| 1 | 1 | **"REHABILITACION DEL LOCAL ESCOLAR N° 064, DEL CENTRO POBLADO PAJARITOS DEL DISTRITO CANOAS DE PUNTA SAL, PROVINCIA DE CONTRALMIRANTE VILLAR - TUMBES"** |  | 155d | 2023-01-02 | 2023-06-30 |  | 0d |  | 3,273,241.49 |  |
| 2 | 1.1 | INICIO DEL PROYECTO | milestone | 0d | 2023-01-02 | 2023-01-02 |  | 12d | 0d |  |  |
| 3 | 1.2 | **ESTRUCTURAS** |  | 155d | 2023-01-02 | 2023-06-30 |  | 0d |  | 1,803,155.45 | 01 |
| 4 | 1.2.1 | **OBRAS PROVISIONALES** |  | 5d | 2023-01-02 | 2023-01-06 |  | 12d |  | 5,864.47 | 01.01 |
| 5 | 1.2.1.1 | SUMINISTRO Y COLOCACION DE CARTEL DE OBRA DE 2.40 x 3.60m |  | 1d | 2023-01-02 | 2023-01-02 | 2 | 12d | 0d | 1,023.55 | 01.01.01 |
| 6 | 1.2.1.2 | CASETA DE GUARDIANIA Y/O ALMACEN |  | 2d | 2023-01-03 | 2023-01-04 | 5 | 12d | 0d | 3,301.92 | 01.01.02 |
| 7 | 1.2.1.3 | CERCO PROVISIONAL EN OBRA DE CALAMINA GALVANIZADA h=2.20m |  | 2d | 2023-01-05 | 2023-01-06 | 6 | 12d | 0d | 1,539 | 01.01.03 |
| 8 | 1.2.2 | **TRABAJOS PRELIMINARES** |  | 140d | 2023-01-05 | 2023-06-16 |  | 12d |  | 52,288.21 | 01.02 |
| 9 | 1.2.2.1 | TRAZO, NIVELES Y REPLANTEO |  | 6d | 2023-01-05 | 2023-01-11 | 7SS | 12d | 0d | 5,005.47 | 01.02.01 |
| 10 | 1.2.2.2 | LIMPIEZA INICIAL DE OBRA |  | 4d | 2023-01-05 | 2023-01-09 | 9SS | 12d | 0d | 1,651.29 | 01.02.02 |
| 11 | 1.2.2.3 | MOVILIZACION Y DESMOVILIZACION DE EQUIPO |  | 30d | 2023-01-05 | 2023-02-08 | 10SS | 12d | 0d | 6,492.48 | 01.02.03 |
| 12 | 1.2.2.4 | TALA DE ARBOLES INC/REFORESTACION |  | 2d | 2023-01-05 | 2023-01-06 | 11SS | 12d | 0d | 1,032.12 | 01.02.04 |
| 13 | 1.2.2.5 | ALQUILER DE BAÑOS QUIMICOS EN OBRA |  | 140d | 2023-01-05 | 2023-06-16 | 12SS | 12d | 0d | 14,760 | 01.02.05 |
| 14 | 1.2.2.6 | **DEMOLICION Y DESMONTAJE** |  | 10d | 2023-01-06 | 2023-01-17 |  | 141d |  | 23,346.85 | 01.02.06 |
| 15 | 1.2.2.6.1 | DEMOLICION DE EDIFICACION EXISTENTE C/MAQUINARIA |  | 10d | 2023-01-06 | 2023-01-17 | 13SS+1d | 141d | 0d | 9,785.29 | 01.02.06.01 |
| 16 | 1.2.2.6.2 | DEMOLICION MANUAL DE VEREDASS Y CUNETAS EXISTENTE |  | 10d | 2023-01-06 | 2023-01-17 | 15SS | 141d | 0d | 5,392.68 | 01.02.06.02 |
| 17 | 1.2.2.6.3 | DESMONTAJE DE COBERTURA EN EDIFICACION EXISTENTE |  | 10d | 2023-01-06 | 2023-01-17 | 16SS | 141d | 0d | 2,362.73 | 01.02.06.03 |
| 18 | 1.2.2.6.4 | DESMONTAJE DE CERCO, VENTANAS Y PUERTAS METALICAS |  | 10d | 2023-01-06 | 2023-01-17 | 17SS | 141d | 0d | 943.54 | 01.02.06.04 |
| 19 | 1.2.2.6.5 | DESMONTAJE DE AULA PREFABRICADA EXISTENTE MANUAL |  | 10d | 2023-01-06 | 2023-01-17 | 18SS | 141d |  | 4,862.61 | 01.02.06.05 |
| 20 | 1.2.3 | **SEGURIDAD EN OBRA Y PLAN PARA LA VIGILANCIA, PREVENCION Y CONTROL DE LA COVID-19** |  | 140d | 2023-01-05 | 2023-06-16 |  | 12d |  | 12,312.45 | 01.03 |
| 21 | 1.2.3.1 | **SEGURIDAD EN OBRA** |  | 140d | 2023-01-05 | 2023-06-16 |  | 12d |  | 7,681.23 | 01.03.01 |
| 22 | 1.2.3.1.1 | EQUIPO DE PROTECCION COLECCTIVA |  | 140d | 2023-01-05 | 2023-06-16 | 13SS | 12d | 0d | 2,444.6 | 01.03.01.01 |
| 23 | 1.2.3.1.2 | EQUIPO DE PROTECCION INDIVIDUAL |  | 140d | 2023-01-05 | 2023-06-16 | 22SS | 12d | 0d | 3,852.5 | 01.03.01.02 |
| 24 | 1.2.3.1.3 | SEÑALIZACION TEMPORAL EN OBRA |  | 140d | 2023-01-05 | 2023-06-16 | 23SS | 12d | 0d | 1,384.13 | 01.03.01.03 |

| ID | WBS | Task | Duration | Start | Finish | Predecessors | Total slack | Free slack | Cost | Text1 |
| --- | --- | --- | --- | --- | --- | --- | --- | --- | --- | --- |
| 25 | 1.2.3.2 | **PLAN PARA LA PREVENCION Y CONTROL ANTE LA COVID-19 EN OBRA** | 140d | 2023-01-05 | 2023-06-16 |  | 12d |  | 4,631.22 | 01.03.02 |
| 26 | 1.2.3.2.1 | ELABORACION, IMPLEMENTACION Y ADMINISTRACION DEL PLAN DE SEGURIDAD Y SALUD EN EL TRABAJO FRENTE AL COVID - 19 | 140d | 2023-01-05 | 2023-06-16 | 24SS | 12d | 0d | 500 | 01.03.02.01 |
| 27 | 1.2.3.2.2 | EQUIPO DE PROTECCION INDIVIDUAL PARA PERSONAL DE OBRA | 140d | 2023-01-05 | 2023-06-16 | 26SS | 12d | 0d | 1,035 | 01.03.02.02 |
| 28 | 1.2.3.2.3 | EQUIPO DE PROTECCION INDIVIDUAL PARA DIRECCION DE OBRA | 140d | 2023-01-05 | 2023-06-16 | 27SS | 12d | 0d | 75 | 01.03.02.03 |
| 29 | 1.2.3.2.4 | EQUIPO DE PROTECCION INDIVIDUAL PARA PERSONAL DE SALUD | 140d | 2023-01-05 | 2023-06-16 | 28SS | 12d | 0d | 75 | 01.03.02.04 |
| 30 | 1.2.3.2.5 | EQUIPO DE PROTECCION INDIVIDUAL PARA VISITANTES | 140d | 2023-01-05 | 2023-06-16 | 29SS | 12d | 0d | 225 | 01.03.02.05 |
| 31 | 1.2.3.2.6 | KIT PARA LAVADO Y DESINFECCION DE PERSONAL | 140d | 2023-01-05 | 2023-06-16 | 30SS | 12d | 0d | 1,721.22 | 01.03.02.06 |
| 32 | 1.2.3.2.7 | EQUIPAMIENTO PARA VIGILANCIA DE LA SALUD DEL TRABAJADOR | 140d | 2023-01-05 | 2023-06-16 | 31SS | 12d |  | 1,000 | 01.03.02.07 |
| 33 | 1.2.4 | **PLAN DE MANEJO AMBIENTAL** | 140d | 2023-01-02 | 2023-06-13 |  | 0d |  | 42,175.15 | 01.04 |
| 34 | 1.2.4.1 | PLAN DE MANEJO AMBIENTAL | 140d | 2023-01-02 | 2023-06-13 |  | 0d |  | 42,175.15 | 01.04.01 |
| 35 | 1.2.5 | **MOVIMIENTO DE TIERRAS** | 124d | 2023-01-04 | 2023-05-27 |  | 0d |  | 208,880.03 | 01.05 |
| 36 | 1.2.5.1 | CORTE DE TERRENO NATURAL CON MAQUINARIA | 4d | 2023-01-04 | 2023-01-07 | 34SS+2d | 0d |  | 4,423.65 | 01.05.01 |
| 37 | 1.2.5.2 | PERFILADO, NIVELACION Y COMPACTACION DE TERRENO NATURAL CON (MAQUINARIA) | 2d | 2023-01-04 | 2023-01-05 | 36SS | 0d |  | 7,577.02 | 01.05.02 |
| 38 | 1.2.5.3 | PERFILADO, NIVELACION Y COMPACTACION DE TERRENO NATURAL - MANUAL | 11d | 2023-01-04 | 2023-01-16 | 37SS | 0d |  | 9,361.02 | 01.05.03 |
| 39 | 1.2.5.4 | EXCAVACION MANUAL DE ZANJAS P/CIMIENTOS, ZAPATAS Y PISOS | 25d | 2023-01-04 | 2023-02-01 | 38SS | 0d |  | 53,464.73 | 01.05.04 |
| 40 | 1.2.5.5 | RELLENO CON MATERIAL PROPIO - CON EQUIPO LIVIANO | 8d | 2023-03-06 | 2023-03-14 | 60FS-5d | 93d |  | 16,002.12 | 01.05.05 |
| 41 | 1.2.5.6 | CAPA DE MATERIAL DE PRESTAMO - HORMIGON GRUESO (60% DE OVER 2" A 4" + 40% ARENA GRUESA) CON EQUIPO LIVIANO | 10d | 2023-01-24 | 2023-02-03 | 39FS-8d | 0d |  | 25,462 | 01.05.06 |
| 42 | 1.2.5.7 | COLOCACION, COMPACTACIONY NIVELACION DE CAPA DE HORMIGON (CON EQUIPO LIVIANO) | 16d | 2023-05-09 | 2023-05-26 | 124FS-12d | 0d |  | 38,075.36 | 01.05.07 |
| 43 | 1.2.5.8 | COLOCACION, COMPACTACION Y NIVELACION DE CAPA DE AFIRMADO (CON EQUIPO LIVIANO) e=0.10m | 6d | 2023-05-22 | 2023-05-27 | 42FS-5d | 0d |  | 8,981.39 | 01.05.08 |
| 44 | 1.2.5.9 | CAPA DE MATERIAL DE PRESTAMO - HORMIGON GRUESO (60% DE PIEDRA + 40% ARENA GRUESA) e=0.25m CON EQUIPO PESADO | 2d | 2023-02-04 | 2023-02-06 | 41 | 0d |  | 13,706.51 | 01.05.09 |
| 45 | 1.2.5.10 | CAPA DE MATERIAL DE PRESTAMO - AFIRMADO (60% DE AFIRMADO + 40% HORMIGON) e=0.15m CON EQUIPO PESADO | 2d | 2023-02-07 | 2023-02-08 | 44 | 0d |  | 5,973.91 | 01.05.10 |
| 46 | 1.2.5.11 | ELIMINACION DE MATERIAL EXCEDENTE A 2.5 KM DE DISTANCIA DE LA OBRA | 5d | 2023-02-02 | 2023-02-07 | 39 | 123d |  | 25,852.32 | 01.05.11 |
| 47 | 1.2.6 | **OBRAS DE CONCRETO SIMPLE** | 98d | 2023-02-07 | 2023-05-31 |  | 0d |  | 30,558.38 | 01.06 |
| 48 | 1.2.6.1 | SOLADO PROP. 1:8, e=0.10m | 5d | 2023-02-07 | 2023-02-11 | 45SS | 0d |  | 15,174.08 | 01.06.01 |
| 49 | 1.2.6.2 | CIMIENTO DE CONCRETO CICLOPEO PROP. 1:8 + 25% P.M. | 2d | 2023-02-07 | 2023-02-08 | 48SS | 122d |  | 3,618.57 | 01.06.02 |
| 50 | 1.2.6.3 | FALSO PISO PROP. 1:8 C:H, e=0.10m | 8d | 2023-05-23 | 2023-05-31 | 43SS+1d | 0d |  | 11,765.73 | 01.06.03 |

| ID | WBS | Task | Duration | Start | Finish | Predecessors | Total slack | Free slack | Cost | Text1 |
| --- | --- | --- | --- | --- | --- | --- | --- | --- | --- | --- |
| 51 | 1.2.7 | **OBRAS DE CONCRETO ARMADO** | 90d | 2023-02-08 | 2023-05-23 |  | 0d |  | 1,255,575.85 | 01.07 |
| 52 | 1.2.7.1 | **ZAPATAS** | 10d | 2023-02-08 | 2023-02-18 |  | 0d |  | 106,934.55 | 01.07.01 |
| 53 | 1.2.7.1.1 | CONCRETO F'C=210 KG/CM2 - PARA ZAPATAS | 7d | 2023-02-11 | 2023-02-18 | 54FS-5d | 0d |  | 87,418.35 | 01.07.01.01 |
| 54 | 1.2.7.1.2 | ACERO CORRUGADO FY=4200 KG/CM2 GRADO 60 - PARA ZAPATAS | 8d | 2023-02-08 | 2023-02-16 | 48SS+1d | 0d |  | 19,516.2 | 01.07.01.02 |
| 55 | 1.2.7.2 | **VIGA DE CIMENTACION** | 12d | 2023-02-14 | 2023-02-27 |  | 0d |  | 103,579.47 | 01.07.02 |
| 56 | 1.2.7.2.1 | CONCRETO F'C=210 KG/CM2 - EN VIGAS DE CIMENTACION | 4d | 2023-02-23 | 2023-02-27 | 58FS-2d | 0d |  | 24,790.52 | 01.07.02.01 |
| 57 | 1.2.7.2.2 | ACERO CORRUGADO FY=4200 KG/CM2 GRADO 60 - VIGA DE CIMENTACION | 10d | 2023-02-14 | 2023-02-24 | 53FS-5d | 0d |  | 60,868.62 | 01.07.02.02 |
| 58 | 1.2.7.2.3 | ENCOFRADO Y DESENCOFRADO DE VIGA DE CIMENTACION | 10d | 2023-02-14 | 2023-02-24 | 57FS-10d | 0d |  | 17,920.33 | 01.07.02.03 |
| 59 | 1.2.7.3 | **SOBRECIMIENTO ARMADO** | 13d | 2023-02-24 | 2023-03-10 |  | 0d |  | 64,147.21 | 01.07.03 |
| 60 | 1.2.7.3.1 | CONCRETO F'C=175 KG/CM2 - PARA SOBRECIMIENTO ARMADO | 4d | 2023-03-07 | 2023-03-10 | 62FS-2d | 93d | 0d | 20,816.19 | 01.07.03.01 |
| 61 | 1.2.7.3.2 | ACERO CORRUGADO FY=4200 KG/CM2 GRADO 60 - PARA SOBRECIMIENTO ARMADO | 8d | 2023-02-24 | 2023-03-04 | 56SS+1d | 0d |  | 18,604.18 | 01.07.03.02 |
| 62 | 1.2.7.3.3 | ENCOFRADO Y DESENCOFRADO DE SOBRECIMIENTO | 10d | 2023-02-25 | 2023-03-08 | 61SS+1d | 93d | 0d | 24,726.84 | 01.07.03.03 |
| 63 | 1.2.7.4 | **COLUMNAS Y PLACAS** | 29d | 2023-02-27 | 2023-03-31 |  | 0d |  | 386,058.17 | 01.07.04 |
| 64 | 1.2.7.4.1 | CONCRETO F'C=210 KG/CM2 PARA COLUMNAS | 15d | 2023-03-15 | 2023-03-31 | 66FS-12d | 0d |  | 98,302.26 | 01.07.04.01 |
| 65 | 1.2.7.4.2 | ACERO CORRUGADO FY=4200 KG/CM2 GRADO 60 PARA COLUMNA Y PLACAS | 20d | 2023-02-27 | 2023-03-21 | 61SS+2d | 0d |  | 175,284 | 01.07.04.02 |
| 66 | 1.2.7.4.3 | ENCOFRADO Y DESENCOFRADO DE COLUMNA Y PLACAS | 25d | 2023-02-28 | 2023-03-28 | 65SS+1d | 0d |  | 112,471.91 | 01.07.04.03 |
| 67 | 1.2.7.5 | **COLUMNETAS** | 30d | 2023-04-18 | 2023-05-22 |  | 34d |  | 62,087.71 | 01.07.05 |
| 68 | 1.2.7.5.1 | CONCRETO F'C=175 KG/CM2 EN COLUMNETAS | 30d | 2023-04-18 | 2023-05-22 | 123SS | 34d | 0d | 11,386.82 | 01.07.05.01 |
| 69 | 1.2.7.5.2 | ACERO CORRUGADO FY=4200 KG/CM2 GRADO 60 - PARA COLUMNETAS | 30d | 2023-04-18 | 2023-05-22 | 68SS | 34d | 0d | 36,222.7 | 01.07.05.02 |
| 70 | 1.2.7.5.3 | ENCOFRADO Y DESENCOFRADO DE COLUMNETAS | 30d | 2023-04-18 | 2023-05-22 | 69SS | 34d |  | 14,478.19 | 01.07.05.03 |
| 71 | 1.2.7.6 | **VIGAS** | 28d | 2023-03-15 | 2023-04-15 |  | 0d |  | 189,304.61 | 01.07.06 |
| 72 | 1.2.7.6.1 | CONCRETO F'C= 210KG/CM2 EN VIGAS | 8d | 2023-04-07 | 2023-04-15 | 74FS-5d | 33d | 0d | 52,473.83 | 01.07.06.01 |
| 73 | 1.2.7.6.2 | ACERO CORRUGADO FY=4200 KG/CM2 GRADO 60 - PARA VIGAS | 20d | 2023-03-15 | 2023-04-06 | 64SS | 0d |  | 91,679.31 | 01.07.06.02 |
| 74 | 1.2.7.6.3 | ENCOFRADO Y DESENCOFRADO DE VIGAS | 20d | 2023-03-21 | 2023-04-12 | 73SS+5d | 0d |  | 45,151.47 | 01.07.06.03 |

| ID | WBS | Task | Duration | Start | Finish | Predecessors | Total slack | Free slack | Cost | Text1 |
| --- | --- | --- | --- | --- | --- | --- | --- | --- | --- | --- |
| 75 | 1.2.7.7 | **VIGAS DE CIERRE EN MUROS** | 30d | 2023-04-18 | 2023-05-22 |  | 34d |  | 22,534.45 | 01.07.07 |
| 76 | 1.2.7.7.1 | CONCRETO F'C= 175KG/CM2 EN VIGAS DE CIERRE | 30d | 2023-04-18 | 2023-05-22 | 68SS | 34d | 0d | 5,325.85 | 01.07.07.01 |
| 77 | 1.2.7.7.2 | ACERO CORRUGADO FY=4200 KG/CM2 GRADO 60 - VIGA DE CIERRE | 30d | 2023-04-18 | 2023-05-22 | 76SS | 34d | 0d | 9,388 | 01.07.07.02 |
| 78 | 1.2.7.7.3 | ENCOFRADO Y DESENCOFRADO DE VIGAS DE CIERRE | 30d | 2023-04-18 | 2023-05-22 | 77SS | 34d |  | 7,820.6 | 01.07.07.03 |
| 79 | 1.2.7.8 | **LOSA ALIGERADA** | 39d | 2023-03-21 | 2023-05-04 |  | 0d |  | 217,500.75 | 01.07.08 |
| 80 | 1.2.7.8.1 | CONCRETO F'C=210 KG/CM2 EN LOSA ALIGERADA | 15d | 2023-04-18 | 2023-05-04 | 81FS-11d | 0d |  | 48,785.74 | 01.07.08.01 |
| 81 | 1.2.7.8.2 | ACERO CORRUGADO FY=4200 KG/CM2 GRADO 60 - PARA LOSAS ALIGERADA | 35d | 2023-03-21 | 2023-04-29 | 82SS | 0d |  | 41,926.12 | 01.07.08.02 |
| 82 | 1.2.7.8.3 | ENCOFRADO Y DESENCOFRADO DE LOSA ALIGERADA | 35d | 2023-03-21 | 2023-04-29 | 74SS | 0d |  | 81,163.6 | 01.07.08.03 |
| 83 | 1.2.7.8.4 | LADRILLO DE TECHO 15x30x30 - LOSA ALIGERADA | 35d | 2023-03-21 | 2023-04-29 | 82SS | 53d |  | 45,625.29 | 01.07.08.04 |
| 84 | 1.2.7.9 | **LOSA MACIZA** | 41d | 2023-03-21 | 2023-05-06 |  | 47d |  | 14,169.67 | 01.07.09 |
| 85 | 1.2.7.9.1 | CONCRETO F'C=210 KG/CM2 - PARA LOSA MACIZA | 6d | 2023-05-01 | 2023-05-06 | 80FS-4d | 44d | 0d | 4,244.42 | 01.07.09.01 |
| 86 | 1.2.7.9.2 | ACERO CORRUGADO FY=4200 KG/CM2 GRADO 60 - LOSA MACIZA | 35d | 2023-03-21 | 2023-04-29 | 87SS | 53d |  | 1,641.38 | 01.07.09.02 |
| 87 | 1.2.7.9.3 | ENCOFRADO Y DESENCOFRADO DE LOSA MACIZA | 35d | 2023-03-21 | 2023-04-29 | 81SS | 53d | 0d | 8,283.87 | 01.07.09.03 |
| 88 | 1.2.7.10 | **ESCALERA** | 7d | 2023-05-03 | 2023-05-10 |  | 44d |  | 9,329.78 | 01.07.10 |
| 89 | 1.2.7.10.1 | CONCRETO F'C=210 KG/CM2 EN ESCALERA | 1d | 2023-05-10 | 2023-05-10 | 90 | 44d |  | 3,848.64 | 01.07.10.01 |
| 90 | 1.2.7.10.2 | ACERO DE REFUERZO F'Y=4,200 KG/CM2 GRADO 60 PARA ESCALERA | 2d | 2023-05-08 | 2023-05-09 | 91FS-1d | 44d | 0d | 2,337.51 | 01.07.10.02 |
| 91 | 1.2.7.10.3 | ENCOFRADO Y DESENCOFRADO DE ESCALERA | 5d | 2023-05-03 | 2023-05-08 | 85FS-4d | 44d | 0d | 3,143.63 | 01.07.10.03 |
| 92 | 1.2.7.11 | **GRADERIA** | 17d | 2023-05-04 | 2023-05-23 |  | 33d |  | 35,121.13 | 01.07.11 |
| 93 | 1.2.7.11.1 | CONCRETO F'C=175 KG/CM2 EN GRADERIA | 4d | 2023-05-19 | 2023-05-23 | 95 | 33d |  | 10,609.57 | 01.07.12 |
| 94 | 1.2.7.11.2 | ACERO DE REFUERZO F'Y=4,200 KG/CM2 GRADO 60 EN GRADERIA | 6d | 2023-05-04 | 2023-05-10 | 117FS-2d | 33d | 0d | 9,306.28 | 01.07.13 |
| 95 | 1.2.7.11.3 | ENCOFRADO Y DESENCOFRADO DE GRADERIAS | 12d | 2023-05-05 | 2023-05-18 | 94SS+1d | 33d | 0d | 15,205.28 | 01.07.14 |
| 96 | 1.2.7.12 | **TANQUE ELEVADO Y CISTERNA** | 26d | 2023-03-17 | 2023-04-15 |  | 65d |  | 44,808.35 | 01.07.15 |
| 97 | 1.2.7.12.1 | CONCRETO PARA CISTERNA Y TANQUE ELEVADO | 6d | 2023-04-10 | 2023-04-15 | 99FS-2d | 65d |  | 12,231.07 | 01.07.15.01 |
| 98 | 1.2.7.12.2 | ACERO DE REFUERZO F'Y=4,200 KG/CM2 GRADO 60 EN GRADERIA | 10d | 2023-03-17 | 2023-03-28 | 64SS+2d | 65d | 0d | 17,308.51 | 01.07.15.02 |
| 99 | 1.2.7.12.3 | ENCOFRADO Y DESENCOFRADO PARA CISTERNA Y TANQUE ELEVADO | 20d | 2023-03-20 | 2023-04-11 | 98SS+2d | 65d | 0d | 15,268.77 | 01.07.15.03 |

| ID | WBS | Task | Duration | Start | Finish | Predecessors | Total slack | Free slack | Cost | Text1 |
| --- | --- | --- | --- | --- | --- | --- | --- | --- | --- | --- |
| 100 | 1.2.8 | **COBERTURAS LIVIANAS** | 20d | 2023-04-13 | 2023-05-05 |  | 33d |  | 193,671.26 | 01.08 |
| 101 | 1.2.8.1 | SUMINISTRO Y COLOCACION DE TIJERAL METALICO CURVO TIPO 1 LONG=24.63M | 20d | 2023-04-13 | 2023-05-05 | 72SS+5d | 33d | 0d | 28,452.44 | 01.08.01 |
| 102 | 1.2.8.2 | SUMINISTRO Y COLOCACION DE TIJERAL METALICO RECTANGULAR TIPO 2 LONG=6.55M | 20d | 2023-04-13 | 2023-05-05 | 101SS | 33d | 0d | 14,866.16 | 01.08.02 |
| 103 | 1.2.8.3 | SUMINISTRO Y COLOCACION DE TUBO RECT. 4" x2" x 2.5mm | 20d | 2023-04-13 | 2023-05-05 | 102SS | 33d | 0d | 141.96 | 01.08.03 |
| 104 | 1.2.8.4 | SUMINISTRO Y COLOCACION DE VIGUETA METALICA TIPO VG-C | 20d | 2023-04-13 | 2023-05-05 | 103SS | 33d | 0d | 47,936.33 | 01.08.04 |
| 105 | 1.2.8.5 | SUMINISTRO Y COLOCACION DE VIGUETA METALICA DE PERFIL "C" 4" x 2" e=2.00mm | 20d | 2023-04-13 | 2023-05-05 | 104SS | 33d | 0d | 7,216.13 | 01.08.05 |
| 106 | 1.2.8.6 | SUMINISTRO Y COLOCACION DE TEMPLADOR DE Ø 5/8" | 20d | 2023-04-13 | 2023-05-05 | 105SS | 33d | 0d | 4,390 | 01.08.06 |
| 107 | 1.2.8.7 | SUMINISTRO Y COLOCACION DE TEMPLADOR DE Ø 3/8" | 20d | 2023-04-13 | 2023-05-05 | 106SS | 33d | 0d | 1,608.6 | 01.08.07 |
| 108 | 1.2.8.8 | SUMINISTRO Y COLOCACION DE TENSORES DE FIERRO LISO Ø 1" | 20d | 2023-04-13 | 2023-05-05 | 107SS | 33d | 0d | 3,463 | 01.08.08 |
| 109 | 1.2.8.9 | SUMINISTRO Y COLOCACION DE COLGANTE DE FIERRO LISO Ø 1/2" | 20d | 2023-04-13 | 2023-05-05 | 108SS | 33d | 0d | 665.76 | 01.08.09 |
| 110 | 1.2.8.10 | SUMINISTRO Y COLOCACION DE COBERTURA DE ACERO ALUMINIZADO (CALAMINON CU e=0.50mm) | 20d | 2023-04-13 | 2023-05-05 | 109SS | 33d | 0d | 55,149.6 | 01.08.10 |
| 111 | 1.2.8.11 | SUMINISTRO Y COLOCACION DE COBERTURA DE ACERO ALUMINIZADO (CALAMINON TI e=0.35mm) | 20d | 2023-04-13 | 2023-05-05 | 110SS | 33d | 0d | 7,898.02 | 01.08.11 |
| 112 | 1.2.8.12 | SUMINISTRO Y COLOCACION DE APOYOS FIJOS ENTRE COLUMNA Y TIJERAL PARABOLICO | 20d | 2023-04-13 | 2023-05-05 | 111SS | 33d | 0d | 1,319.08 | 01.08.12 |
| 113 | 1.2.8.13 | SUMINISTRO Y COLOCACION DE APOYOS MOVIL ENTRE COLUMNA Y TIJERAL PARABOLICO | 20d | 2023-04-13 | 2023-05-05 | 112SS | 33d | 0d | 1,830.44 | 01.08.13 |
| 114 | 1.2.8.14 | SUMINISTRO Y COLOCACION DE TUBO CUADRADO DE 4"x4"x3.00mm INC. DADO DE 0.40x0.40x0.60 | 20d | 2023-04-13 | 2023-05-05 | 113SS | 33d | 0d | 4,064 | 01.08.14 |
| 115 | 1.2.8.15 | SUMINISTRO Y COLOCACION DE ARRIOSTRE DE FIERRO CORRUGADO Ø 3/8" | 20d | 2023-04-13 | 2023-05-05 | 114SS | 33d | 0d | 4,870.8 | 01.08.15 |
| 116 | 1.2.8.16 | SUMINISTRO Y COLOCACION DE CANALETA DE PLANCHA GALVANIZADA 2mm (0.25x0.15x0.15m) | 20d | 2023-04-13 | 2023-05-05 | 115SS | 33d | 0d | 9,053.98 | 01.08.16 |
| 117 | 1.2.8.17 | SUMINISTRO Y COLOCACION DE BAJADA DE MONTANTE DE TUBERIA PVC Ø 3" | 20d | 2023-04-13 | 2023-05-05 | 116SS | 33d | 0d | 744.96 | 01.08.17 |
| 118 | 1.2.9 | **OTROS** | 3d | 2023-06-28 | 2023-06-30 |  | 0d |  | 1,829.65 | 01.09 |
| 119 | 1.2.9.1 | JUNTAS DE DILATACION ASFALTICA e=1" EN CERCO PERIMETRICO | 2d | 2023-06-28 | 2023-06-29 | 215 | 0d |  | 178.36 | 01.09.01 |
| 120 | 1.2.9.2 | LIMPIEZA FINAL DE OBRA | 2d | 2023-06-29 | 2023-06-30 | 119FS-1d | 0d |  | 1,651.29 | 01.09.02 |
| 121 | 1.3 | **ARQUITECTURA** | 61d | 2023-04-18 | 2023-06-27 |  | 0d |  | 885,634.6 | 02 |
| 122 | 1.3.1 | **MUROS Y TABIQUES** | 30d | 2023-04-18 | 2023-05-22 |  | 0d |  | 61,516.74 | 02.01 |
| 123 | 1.3.1.1 | MURO DE LADRILLO TIPO IV (12.5x9x23) APAREJO DE SOGA | 30d | 2023-04-18 | 2023-05-22 | 80SS | 0d |  | 50,073.74 | 02.01.01 |
| 124 | 1.3.1.2 | MURO DE LADRILLO TIPO IV (12.5x9x23) APAREJO DE CABEZA | 30d | 2023-04-18 | 2023-05-22 | 123SS | 0d |  | 11,443 | 02.01.02 |

| ID | WBS | Task | Duration | Start | Finish | Predecessors | Total slack | Free slack | Cost | Text1 |
| --- | --- | --- | --- | --- | --- | --- | --- | --- | --- | --- |
| 125 | 1.3.2 | **REVOQUES Y ENLUCIDOS** | 25d | 2023-05-23 | 2023-06-20 |  | 0d |  | 173,879.57 | 02.02 |
| 126 | 1.3.2.1 | TARRAJEO EN MUROS EXTERIORES CA 1:4, e=1.5cm, CEMENTO TIPO ICO | 25d | 2023-05-23 | 2023-06-20 | 50SS | 0d |  | 32,169.52 | 02.02.01 |
| 127 | 1.3.2.2 | TARRAJEO EN MUROS INTERIORES CA 1:4, e=1.5cm, CEMENTO TIPO ICO | 25d | 2023-05-23 | 2023-06-20 | 126SS | 0d |  | 19,754.26 | 02.02.02 |
| 128 | 1.3.2.3 | TARRAJEO EN COLUMNAS PROP. 1:5 e=1.5cm, CEMENTO TIPO ICO | 25d | 2023-05-23 | 2023-06-20 | 127SS | 0d |  | 33,155.13 | 02.02.03 |
| 129 | 1.3.2.4 | TARRAJEO EN CIELO RASO PROP. 1:5, e=1.5cm, CEMENTO TIPO ICO | 25d | 2023-05-23 | 2023-06-20 | 128SS | 0d |  | 48,231.35 | 02.02.04 |
| 130 | 1.3.2.5 | TARRAJEO DE VIGAS PROP. 1:4, e=1.5cm, CEMENTO TIPO ICO | 25d | 2023-05-23 | 2023-06-20 | 129SS | 0d |  | 23,281.15 | 02.02.05 |
| 131 | 1.3.2.6 | TARRAJEO DE RAYADO PRIMARIO MEZCLA 1:4 | 25d | 2023-05-23 | 2023-06-20 | 130SS | 0d |  | 6,706.19 | 02.02.06 |
| 132 | 1.3.2.7 | TARRAJEO DE SOBRECIMIENTO PROP. 1:4 e=1.5cm CEMENTO TIPO ICO | 25d | 2023-05-23 | 2023-06-20 | 131SS | 0d |  | 53.34 | 02.02.07 |
| 133 | 1.3.2.8 | REVESTIMIENTO DE DERRAMES h=0.15m, PROP. 1:4, e=1.5cm, CEMENTO TIPO ICO | 25d | 2023-05-23 | 2023-06-20 | 132SS | 0d |  | 7,534.63 | 02.02.08 |
| 134 | 1.3.2.9 | TARRAJEO DE GRADERIAS ACABADO SEMI-PULIDO e=1.5cm CEMENTO TIPO ICO INC. BRUÑADO | 25d | 2023-05-23 | 2023-06-20 | 133SS | 0d |  | 2,994 | 02.02.09 |
| 135 | 1.3.3 | **PINTURA** | 15d | 2023-06-09 | 2023-06-26 |  | 0d |  | 92,393.15 | 02.03 |
| 136 | 1.3.3.1 | PINTURA LATEX SATINADA EN MUROS EXTERIORES | 15d | 2023-06-09 | 2023-06-26 | 134FS-10d | 0d |  | 20,128.24 | 02.03.01 |
| 137 | 1.3.3.2 | PINTURA LATEX SATINADA EN MUROS INTERIORES | 15d | 2023-06-09 | 2023-06-26 | 136SS | 0d |  | 18,419.65 | 02.03.02 |
| 138 | 1.3.3.3 | PINTURA LATEX SATINADA EN COLUMNAS | 15d | 2023-06-09 | 2023-06-26 | 137SS | 0d |  | 16,399.44 | 02.03.03 |
| 139 | 1.3.3.4 | PINTURA LATEX SATINADA EN CIELO RASO | 15d | 2023-06-09 | 2023-06-26 | 138SS | 0d |  | 19,534.72 | 02.03.04 |
| 140 | 1.3.3.5 | PINTURA LATEX SATINADA EN VIGAS | 15d | 2023-06-09 | 2023-06-26 | 139SS | 0d |  | 10,628.66 | 02.03.05 |
| 141 | 1.3.3.6 | PINTURA LATEX SATINADA EN DERRAMES | 15d | 2023-06-09 | 2023-06-26 | 140SS | 0d |  | 1,655.01 | 02.03.06 |
| 142 | 1.3.3.7 | PINTURA ESMALTE SINTETICO a=5cm | 15d | 2023-06-09 | 2023-06-26 | 141SS | 0d |  | 1,739.14 | 02.03.07 |
| 143 | 1.3.3.8 | PINTURA ESMALTE EN CONTRAZOCALO DE CEMENTO h=0.30m | 15d | 2023-06-09 | 2023-06-26 | 142SS | 0d |  | 1,640.16 | 02.03.08 |
| 144 | 1.3.3.9 | PINTURA ESMALTE EN CONTRAZOCALO DE CEMENTO h=0.10m | 15d | 2023-06-09 | 2023-06-26 | 143SS | 0d |  | 1,862.55 | 02.03.09 |
| 145 | 1.3.3.10 | PINTURA ESMALTE EN CONTRA PASO DE TRIBUNA h=0.40m | 15d | 2023-06-09 | 2023-06-26 | 144SS | 0d |  | 385.58 | 02.03.10 |
| 146 | 1.3.4 | **PISOS Y PAVIMENTOS** | 20d | 2023-05-22 | 2023-06-13 |  | 15d |  | 216,986.18 | 02.04 |
| 147 | 1.3.4.1 | CONTRAPISO C:A PROP. 1:4, e=2.5cm | 20d | 2023-05-22 | 2023-06-13 | 43SS | 15d | 0d | 22,942.64 | 02.04.01 |
| 148 | 1.3.4.2 | PISO CERAMICO 0.30 x 0.30 ANTIDESLIZANTE, ALTO TRANSITO | 20d | 2023-05-22 | 2023-06-13 | 147SS | 15d | 0d | 35,196.02 | 02.04.02 |
| 149 | 1.3.4.3 | ENCHAPE CERAMICO (0.30x0.30) | 20d | 2023-05-22 | 2023-06-13 | 148SS | 15d | 0d | 1,863.85 | 02.04.03 |
| 150 | 1.3.4.4 | CONCRETO EN VEREDAS F'C=175 KG/CM2, e=10cm, ACABADO FROTACHADO FINO Y BRUÑADO | 20d | 2023-05-22 | 2023-06-13 | 149SS | 15d | 0d | 66,664.87 | 02.04.04 |
| 151 | 1.3.4.5 | PISO CEMENTO FROTACHADO FINO Y BRUÑADO | 20d | 2023-05-22 | 2023-06-13 | 150SS | 15d | 0d | 9,076.69 | 02.04.05 |
| 152 | 1.3.4.6 | PISO DE ADOQUIN DE CONCRETO h=4cm | 20d | 2023-05-22 | 2023-06-13 | 151SS | 15d | 0d | 15,476.64 | 02.04.06 |
| 153 | 1.3.4.7 | LOSA DEPORTIVA DE C° F'C=175 KG/CM2, e=0.15m INC. ENCOFRADO Y DESENCOFRADO | 20d | 2023-05-22 | 2023-06-13 | 152SS | 15d | 0d | 57,385.86 | 02.04.07 |
| 154 | 1.3.4.8 | LOSA de Cº F'C=210 KG/CM2, e=20cm INC. ENCOFRADO Y DESENCOFRADO | 20d | 2023-05-22 | 2023-06-13 | 153SS | 15d | 0d | 8,040.37 | 02.04.08 |
| 155 | 1.3.4.9 | CORTE EN FALSO PISO | 20d | 2023-05-22 | 2023-06-13 | 154SS | 15d | 0d | 129.74 | 02.04.09 |
| 156 | 1.3.4.10 | CORTE EN CONTRA PISO | 20d | 2023-05-22 | 2023-06-13 | 155SS | 15d | 0d | 209.5 | 02.04.10 |

| ID | WBS | Task | Duration | Start | Finish | Predecessors | Total slack | Free slack | Cost | Text1 |
| --- | --- | --- | --- | --- | --- | --- | --- | --- | --- | --- |
| 157 | 1.3.5 | **ZOCALOS Y CONTRAZOCALOS** | 20d | 2023-05-22 | 2023-06-13 |  | 15d |  | 25,632.4 | 02.05 |
| 158 | 1.3.5.1 | ZOCALO DE CERAMICO 0.30 x 0.30m | 20d | 2023-05-22 | 2023-06-13 | 156SS | 15d | 0d | 13,711.71 | 02.05.01 |
| 159 | 1.3.5.2 | CONTRA ZOCALO DE CERAMICA e=0.10m | 20d | 2023-05-22 | 2023-06-13 | 158SS | 15d | 0d | 7,112.85 | 02.05.02 |
| 160 | 1.3.5.3 | CONTRA ZOCALO DE CEMENTO H= 0.30m e=1.5cm | 20d | 2023-05-22 | 2023-06-13 | 159SS | 15d | 0d | 3,512.58 | 02.05.03 |
| 161 | 1.3.5.4 | CONTRA ZOCALO DE CEMENTO H= 0.10m e=1.5cm | 20d | 2023-05-22 | 2023-06-13 | 160SS | 15d |  | 1,295.26 | 02.05.04 |
| 162 | 1.3.6 | **CARPINTERIA DE MADERA** | 15d | 2023-06-03 | 2023-06-20 |  | 9d |  | 78,196.24 | 02.06 |
| 163 | 1.3.6.1 | SUMINISTRO Y COLOCACION DE PUERTAS DE MADERA CEDRO MACHIEMMBRADA (1.00X2.30M) CON VISOR DE VIDRIO E=6MM, CON LAMINA DE SEGURIDAD Y CERRAJERIA | 15d | 2023-06-03 | 2023-06-20 | 145FS-20d | 9d | 0d | 17,203.4 | 02.06.01 |
| 164 | 1.3.6.2 | SUMINISTRO Y COLOCACION DE PUERTAS DE MADERA CEDRO MACHIEMMBRADA (0.90X2.30M) CON CERRAJERIA | 15d | 2023-06-03 | 2023-06-20 | 163SS | 9d | 0d | 21,258.9 | 02.06.02 |
| 165 | 1.3.6.3 | SUMINISTRO Y COLOCACION DE PUERTAS DE MADERA CEDRO MACHIEMMBRADA (1.00X2.30M) CON CERRAJERIA | 15d | 2023-06-03 | 2023-06-20 | 164SS | 9d | 0d | 3,712.66 | 02.06.03 |
| 166 | 1.3.6.4 | SUMINISTRO Y COLOCACION DE PUERTAS DE MADERA CEDRO MACHIEMMBRADA (0.75X2.30M) CON CERRAJERIA | 15d | 2023-06-03 | 2023-06-20 | 165SS | 9d | 0d | 908 | 02.06.04 |
| 167 | 1.3.6.5 | SUMINISTRO Y COLOCACION DE PUERTAS DE MADERA CONTRAPLACADA (0.75X1.50) CON CERRAJERIA | 15d | 2023-06-03 | 2023-06-20 | 166SS | 9d | 0d | 855 | 02.06.05 |
| 168 | 1.3.6.6 | SUMINISTRO Y COLOCACION DE PUERTAS DE MADERA CONTRAPLACADA (1.10X1.50) CON CERRAJERIA | 15d | 2023-06-03 | 2023-06-20 | 167SS | 9d | 0d | 618.3 | 02.06.06 |
| 169 | 1.3.6.7 | SUMINISTRO Y COLOCACION DE PUERTAS DE MADERA CEDRO MACHIEMMBRADA DOBLE HOJA (1.00X2.30M) CON CERRAJERIA | 15d | 2023-06-03 | 2023-06-20 | 168SS | 9d | 0d | 1,858.33 | 02.06.07 |
| 170 | 1.3.6.8 | SUMINISTRO Y COLOCACION DE PUERTAS DE MADERA CEDRO MACHIEMMBRADA (0.80X2.30) CON CERRAJERIA | 15d | 2023-06-03 | 2023-06-20 | 169SS | 9d | 0d | 2,973.32 | 02.06.08 |
| 171 | 1.3.6.9 | SUMINISTRO Y COLOCACION DE PUERTAS DE MADERA CEDRO MACHIEMMBRADA (1.00X2.10) CON CERRAJERIA | 15d | 2023-06-03 | 2023-06-20 | 170SS | 9d | 0d | 1,696.74 | 02.06.09 |
| 172 | 1.3.6.10 | SUMINISTRO Y COLOCACION DE PUERTAS DE MADERA CONTRAPLACADA (0.90X2.10) CON CERRAJERIA | 15d | 2023-06-03 | 2023-06-20 | 171SS | 9d | 0d | 718.2 | 02.06.10 |
| 173 | 1.3.6.11 | SUMINISTRO Y COLOCACION DE PUERTAS DE MADERA CONTRAPLACADA (0.75X2.10) CON CERRAJERIA | 15d | 2023-06-03 | 2023-06-20 | 172SS | 9d | 0d | 1,197 | 02.06.11 |
| 174 | 1.3.6.12 | SUMINISTRO Y COLOCACION DE REPOSTERO DE MELAMINE TIPO 1 H=0.70M, SEGÚN DISEÑO | 15d | 2023-06-03 | 2023-06-20 | 173SS | 9d | 0d | 9,655.95 | 02.06.12 |
| 175 | 1.3.6.13 | SUMINISTRO Y COLOCACION DE REPOSTERO DE MELAMINE TIPO 2 H=0.70M, SEGÚN DISEÑO | 15d | 2023-06-03 | 2023-06-20 | 174SS | 9d | 0d | 8,318.64 | 02.06.13 |
| 176 | 1.3.6.14 | DIVISIONES DE MELAMINE RESISTENTE A LA HUMEDAD TIPO RH SANITARIO CON PUERTA, SEGUN DISEÑO, INCLUYE ACCESORIOS METALICOS | 15d | 2023-06-03 | 2023-06-20 | 175SS | 9d | 0d | 1,761.06 | 02.06.14 |
| 177 | 1.3.6.15 | DIVISIONES DE MELAMINE RESISTENTE A LA HUMEDAD TIPO RH SANITARIO EN URINARIO, INCLUYE ACCESORIOS METALICOS | 15d | 2023-06-03 | 2023-06-20 | 176SS | 9d | 0d | 190.96 | 02.06.15 |
| 178 | 1.3.6.16 | MUROS CON PLANCHAS DE FIBROCEMENTO e=6mm, EN INTERIORES | 15d | 2023-06-03 | 2023-06-20 | 177SS | 9d | 0d | 4,063.29 | 02.06.16 |
| 179 | 1.3.6.17 | MUROS CON PLANCHAS DE FIBRO CEMENTO RESISTENTE A LA HUMEDAD TIPO RH E=6MM, EN INTERIORES | 15d | 2023-06-03 | 2023-06-20 | 178SS | 9d | 0d | 1,206.49 | 02.06.17 |
| 180 | 1.3.7 | **CARPINTERIA METALICA** | 15d | 2023-06-03 | 2023-06-20 |  | 9d |  | 133,724.74 | 02.07 |
| 181 | 1.3.7.1 | SUMINISTRO Y COLOCACION DE PUERTAS METALICAS 1.70X2.60 (TIPO REJA) | 15d | 2023-06-03 | 2023-06-20 | 179SS | 9d | 0d | 2,643.16 | 02.07.01 |
| 182 | 1.3.7.2 | SUMINISTRO Y COLOCACION DE PUERTAS METALICAS 1.00X2.60 (TIPO REJA) | 15d | 2023-06-03 | 2023-06-20 | 181SS | 9d | 0d | 1,555.55 | 02.07.02 |
| 183 | 1.3.7.3 | SUMINISTRO Y COLOCACION DE PUERTAS METALICAS 3.80X2.60 (TIPO REJA) | 15d | 2023-06-03 | 2023-06-20 | 182SS | 9d | 0d | 11,694.92 | 02.07.03 |
| 184 | 1.3.7.4 | SUMINISTRO Y COLOCACION DE VENTANA ENMARCADA EN ALUMINIO Y VIDRIO DE 6MM CON LAMINA DE SEGURIDAD, INC ACCESORIOS, SEGÚN DISEÑO | 15d | 2023-06-03 | 2023-06-20 | 183SS | 9d | 0d | 42,507.96 | 02.07.04 |
| 185 | 1.3.7.5 | SUMINISTRO Y COLOCACION PROTECTOR METALICO PM-1 (4.12X1.75), SEGÚN DISEÑO | 15d | 2023-06-03 | 2023-06-20 | 184SS | 9d | 0d | 1,802.5 | 02.07.05 |
| 186 | 1.3.7.6 | SUMINISTRO Y COLOCACION PROTECTOR METALICO PM-2 (3.11X1.75), SEGÚN DISEÑO | 15d | 2023-06-03 | 2023-06-20 | 185SS | 9d | 0d | 1,355.63 | 02.07.06 |
| 187 | 1.3.7.7 | SUMINISTRO Y COLOCACION PROTECTOR METALICO PM-3 (2.91X1.75), SEGÚN DISEÑO | 15d | 2023-06-03 | 2023-06-20 | 186SS | 9d | 0d | 2,542.38 | 02.07.07 |
| 188 | 1.3.7.8 | SUMINISTRO Y COLOCACION PROTECTOR METALICO PM-4 (3.92X1.75), SEGÚN DISEÑO | 15d | 2023-06-03 | 2023-06-20 | 187SS | 9d | 0d | 3,430 | 02.07.08 |
| 189 | 1.3.7.9 | SUMINISTRO Y COLOCACION PASAMANOS METALICA DE ACERO INOXIDABLE Ø 2" SEGÚN DISEÑO | 15d | 2023-06-03 | 2023-06-20 | 188SS | 9d | 0d | 2,729.29 | 02.07.09 |
| 190 | 1.3.7.10 | BARANDA METALICA DE ACERO INOXIDABLE Ø 2" TIPO 1 SEGÚN DISEÑO H=0.35M | 15d | 2023-06-03 | 2023-06-20 | 189SS | 9d | 0d | 780 | 02.07.10 |
| 191 | 1.3.7.11 | BARANDA METALICA DE ACERO INOXIDABLE Ø 2" TIPO 2 SEGÚN DISEÑO H=0.90M | 15d | 2023-06-03 | 2023-06-20 | 190SS | 9d | 0d | 17,564.4 | 02.07.11 |
| 192 | 1.3.7.12 | SUMINISTRO Y COLOCACION DE TAPA JUNTAS DE 4" PARA PISOS CON PL ACERO GALVANIZADO DE 3mm | 15d | 2023-06-03 | 2023-06-20 | 191SS | 9d | 0d | 143.91 | 02.07.12 |
| 193 | 1.3.7.13 | SUMINISTRO Y COLOCACION DE TAPA JUNTAS DE 4" PARA MUROS Y CIELO RASO CON PL DE ACERO GALVANIZADO DE 3mm | 15d | 2023-06-03 | 2023-06-20 | 192SS | 9d | 0d | 1,227.52 | 02.07.13 |
| 194 | 1.3.7.14 | SUMINISTRO Y COLOCACION DE TAPA JUNTAS EN SEPARACION DE COBERTURA TIPO U Y TIPO L | 15d | 2023-06-03 | 2023-06-20 | 193SS | 9d | 0d | 1,797.6 | 02.07.14 |
| 195 | 1.3.7.15 | SUMINISTRO Y COLOCACION DE ASTA DE BANDERA | 15d | 2023-06-03 | 2023-06-20 | 194SS | 9d | 0d | 6,982.56 | 02.07.15 |
| 196 | 1.3.7.16 | CERCO METALICO CON T°F°N° 1"X2" E=2.00MM H=2.60M | 15d | 2023-06-03 | 2023-06-20 | 195SS | 9d | 0d | 4,638.74 | 02.07.16 |
| 197 | 1.3.7.17 | SUMINISTRO Y COLOCACION DE PARASOLES METALICOS. SEGÚN DISEÑO INC. ACCESORIOS DE SUJECION Y PINTADO | 15d | 2023-06-03 | 2023-06-20 | 196SS | 9d | 0d | 24,123.51 | 02.07.17 |
| 198 | 1.3.7.18 | BARANDA DE ACERO INOXIDABLE P/SS. HH. DISCAPACITADOS L=1.00M | 15d | 2023-06-03 | 2023-06-20 | 197SS | 9d | 0d | 1,450.74 | 02.07.18 |
| 199 | 1.3.7.19 | SUM. Y COLOC. DE COLUMNAS DE T°F° N° 4"x4" INC. PINTADO | 15d | 2023-06-03 | 2023-06-20 | 198SS | 9d | 0d | 4,754.37 | 02.07.19 |

| ID | WBS | Task | Duration | Start | Finish | Predecessors | Total slack | Free slack | Cost | Text1 |
| --- | --- | --- | --- | --- | --- | --- | --- | --- | --- | --- |
| 200 | 1.3.8 | **CERRAJERIA** | 15d | 2023-06-03 | 2023-06-20 |  | 9d |  | 176.4 | 02.08 |
| 201 | 1.3.8.1 | SUMINISTRO Y COLOCACION DE CERROJO ALUMINIZADO DE 2" INCL. MANIJA | 15d | 2023-06-03 | 2023-06-20 | 199SS | 9d |  | 176.4 | 02.08.01 |
| 202 | 1.3.9 | **OTROS** | 31d | 2023-05-23 | 2023-06-27 |  | 3d |  | 103,129.18 | 02.09 |
| 203 | 1.3.9.1 | **JUNTAS DE DILATACION** | 12d | 2023-05-27 | 2023-06-09 |  | 18d |  | 49,772.75 | 02.09.01 |
| 204 | 1.3.9.1.1 | JUNTA DE DILATACION e=1" | 12d | 2023-05-27 | 2023-06-09 | 43SS+5d | 18d | 0d | 2,088.92 | 02.09.01.01 |
| 205 | 1.3.9.1.2 | JUNTA DE DILATACION FLEXIBLEe=3/4" CON POLIURETANO EN LOSAS DEPORTIVA Y PATIOS | 12d | 2023-05-27 | 2023-06-09 | 204SS | 18d | 0d | 1,940.99 | 02.09.01.02 |
| 206 | 1.3.9.1.3 | JUNTA VERTICAL CON SELLO ELASTOMERICO e=1" | 12d | 2023-05-27 | 2023-06-09 | 205SS | 18d | 0d | 2,846.39 | 02.09.01.03 |
| 207 | 1.3.9.1.4 | SARDINEL DE VEREDAS Y RAMPAS 0.20x0.40 F'C=175 KG/CM2 | 12d | 2023-05-27 | 2023-06-09 | 206SS | 18d | 0d | 28,129.12 | 02.09.02 |
| 208 | 1.3.9.1.5 | SARDINEL DE (0.20x0.50 ) F'C=175 KG/CM2 EN LOSAS DEPORTIVA Y PATIOS | 12d | 2023-05-27 | 2023-06-09 | 207SS | 18d | 0d | 11,212.2 | 02.09.03 |
| 209 | 1.3.9.1.6 | SARDINEL DE (0.20x0.60 ) F'C=175 KG/CM2 | 12d | 2023-05-27 | 2023-06-09 | 208SS | 18d | 0d | 637.91 | 02.09.04 |
| 210 | 1.3.9.1.7 | BRUÑAS e=1cm EN MUROS EXTERIORES E INTERIORES | 12d | 2023-05-27 | 2023-06-09 | 209SS | 18d |  | 2,917.22 | 02.09.05 |
| 211 | 1.3.9.2 | **SEÑALES INFORMATIVAS DE SEGURIDAD** | 3d | 2023-06-24 | 2023-06-27 |  | 0d |  | 3,393.95 | 02.09.06 |
| 212 | 1.3.9.2.1 | SUMINISTRO Y COLOCACION DE SEÑALIZACION ADOSADO A PARED 0.20x0.30m | 3d | 2023-06-24 | 2023-06-27 | 145FS-2d | 0d |  | 1,934.52 | 02.09.06.01 |
| 213 | 1.3.9.2.2 | SUMINISTRO Y COLOCACION DE SEÑALIZACION ADOSADO A PARED 0.30x0.40m | 3d | 2023-06-24 | 2023-06-27 | 212SS | 0d |  | 300.24 | 02.09.06.02 |
| 214 | 1.3.9.2.3 | SUMINISTRO E INSTALACION DE EXTINTORES | 3d | 2023-06-24 | 2023-06-27 | 213SS | 0d |  | 966.85 | 02.09.06.03 |
| 215 | 1.3.9.2.4 | SUMINISTRO Y COLOCACION DE GARGOLAS DE C° PREFABRICADA | 3d | 2023-06-24 | 2023-06-27 | 214SS | 0d |  | 192.34 | 02.09.07 |
| 216 | 1.3.9.3 | **MESAS DE CONCRETO** | 8d | 2023-05-23 | 2023-05-31 |  | 26d |  | 49,962.48 | 02.09.08 |
| 217 | 1.3.9.3.1 | CONCRETO F'C=175 KG/CM2 PARA MESAS | 8d | 2023-05-23 | 2023-05-31 | 50SS | 26d | 0d | 496.47 | 02.09.08.01 |
| 218 | 1.3.9.3.2 | ACERO F'Y=4200 KG/CM2 PARA MESAS | 8d | 2023-05-23 | 2023-05-31 | 217SS | 26d | 0d | 432.36 | 02.09.08.02 |
| 219 | 1.3.9.3.3 | ENCOFRADO Y DESENCOFRADO DE MESAS DE CONCRETO | 8d | 2023-05-23 | 2023-05-31 | 218SS | 26d | 0d | 796.34 | 02.09.08.03 |
| 220 | 1.3.9.3.4 | SUMINISTRO Y COLOCACION DE LETRAS DE ACERO INOXIDABLE SATINADO | 8d | 2023-05-23 | 2023-05-31 | 219SS | 26d | 0d | 3,676.66 | 02.09.09 |
| 221 | 1.3.9.3.5 | SUMINISTRO Y COLOCACION DE INSIGNIA METALICA DE ACERO INOXIDABLE SATINADO | 8d | 2023-05-23 | 2023-05-31 | 220SS | 26d | 0d | 1,225.99 | 02.09.10 |
| 222 | 1.3.9.3.6 | SUMINISTRO Y COLOCACION DE LADRILLO PASTELERO EN COBERTURAS | 8d | 2023-05-23 | 2023-05-31 | 221SS | 26d | 0d | 36,349.64 | 02.09.11 |
| 223 | 1.3.9.3.7 | CONTRAZOCALO H= 0.10m INC. MEDIA CAÑA PARA EVACUACION PLUVIAL EN CORREDORES Y COBERTURAS | 8d | 2023-05-23 | 2023-05-31 | 222SS | 26d | 0d | 4,088.93 | 02.09.12 |
| 224 | 1.3.9.3.8 | CONCRETO F´C=175KG/CM2 PARA REDIRECCIONAMIENTO DE AGUA PLUVIAL EN CANALETA MEDIA CAÑA | 8d | 2023-05-23 | 2023-05-31 | 223SS | 26d | 0d | 333.29 | 02.09.13 |
| 225 | 1.3.9.3.9 | RED DE DISTRIBUCION PVC SAP PARA BAJANTE DE DRENAJE PLUVIAL Ø 4" INCLUYE ACCESORIOS | 8d | 2023-05-23 | 2023-05-31 | 224SS | 26d | 0d | 2,144.4 | 02.09.14 |
| 226 | 1.3.9.3.10 | SUMINISTRO E INSTALACION DE CODO DE 90° Ø 4" PVC PARA DRENAJE PLUVIAL | 8d | 2023-05-23 | 2023-05-31 | 225SS | 26d |  | 418.4 | 02.09.15 |

| ID | WBS | Task | Duration | Start | Finish | Predecessors | Total slack | Free slack | Cost | Text1 |
| --- | --- | --- | --- | --- | --- | --- | --- | --- | --- | --- |
| 227 | 1.4 | **INSTALACIONES SANITARIAS** | 63d | 2023-04-10 | 2023-06-21 |  | 8d |  | 120,413.37 | 03 |
| 228 | 1.4.1 | **TRABAJOS PRELIMINARES** | 6d | 2023-04-10 | 2023-04-15 |  | 8d |  | 723.37 | 03.01 |
| 229 | 1.4.1.1 | TRAZO, NIVEL Y REPLANTEO DE RED DE AGUA FRIA Y ALCANTARILLADO | 6d | 2023-04-10 | 2023-04-15 | 42SS-25d | 8d | 0d | 535.38 | 03.01.01 |
| 230 | 1.4.1.2 | TRAZO, NIVEL Y REPLANTEO DE BIODIGESTOR, CUNETAS | 6d | 2023-04-10 | 2023-04-15 | 229SS | 8d | 0d | 187.99 | 03.01.02 |
| 231 | 1.4.2 | **MOVIMIENTO DE TIERRAS** | 28d | 2023-04-10 | 2023-05-11 |  | 8d |  | 16,285.22 | 03.02 |
| 232 | 1.4.2.1 | EXCAVACION DE ZANJAS MANUAL | 6d | 2023-04-10 | 2023-04-15 | 230SS | 8d | 0d | 6,302.6 | 03.02.01 |
| 233 | 1.4.2.2 | SUMINISTRO Y COLOCACION DE CAMA DE ARENA FINA, e=0.10m | 4d | 2023-04-12 | 2023-04-15 | 232SS+2d | 8d | 0d | 914.74 | 03.02.02 |
| 234 | 1.4.2.3 | SUMINISTRO Y COLOCACION DE CAPA DE PROTECCION CON ARENA FINA, e=0.15m | 4d | 2023-05-04 | 2023-05-08 | 294 | 43d | 0d | 1,372.6 | 03.02.03 |
| 235 | 1.4.2.4 | RELLENO CON MATERIAL PROPIO COMPACTADO - EQUIPO LIVIANO | 3d | 2023-05-09 | 2023-05-11 | 234 | 43d |  | 1,277.02 | 03.02.04 |
| 236 | 1.4.2.5 | SUMINISTRO Y COLOCACION DE CAPA DE HORMIGON PARA CUNETA, e=0.25m | 5d | 2023-04-13 | 2023-04-18 | 233SS+1d | 8d | 0d | 1,592.06 | 03.02.05 |
| 237 | 1.4.2.6 | ACARREO MANUAL DE MATERIAL EXCEDENTE | 3d | 2023-04-17 | 2023-04-19 | 232 | 59d | 0d | 3,545.43 | 03.02.06 |
| 238 | 1.4.2.7 | ELIMINACION DE MATERIAL EXCEDENTE A 2.5 KM DE DISTANCIA DE LA OBRA | 3d | 2023-04-20 | 2023-04-22 | 237 | 59d |  | 1,280.77 | 03.02.07 |
| 239 | 1.4.3 | **INSTALACIONES DE AGUA FRIA** | 15d | 2023-04-14 | 2023-05-01 |  | 8d |  | 7,407.29 | 03.03 |
| 240 | 1.4.3.1 | SALIDA DE AGUA FRIA CON TUBERIA DE PVC-SAP Ø 1/2" | 15d | 2023-04-14 | 2023-05-01 | 236SS+1d | 8d | 0d | 1,579.3 | 03.03.01 |
| 241 | 1.4.3.2 | RED DE DISTRIBUCION TUBERIA Ø 1/2" PVC SAP | 15d | 2023-04-14 | 2023-05-01 | 240SS | 8d | 0d | 425.01 | 03.03.02 |
| 242 | 1.4.3.3 | RED DE DISTRIBUCION TUBERIA Ø 3/4" PVC SAP | 15d | 2023-04-14 | 2023-05-01 | 241SS | 8d | 0d | 193.12 | 03.03.03 |
| 243 | 1.4.3.4 | RED DE DISTRIBUCION TUBERIA Ø 1" PVC-SAP | 15d | 2023-04-14 | 2023-05-01 | 242SS | 8d | 0d | 817.92 | 03.03.04 |
| 244 | 1.4.3.5 | RED DE DISTRIBUCION TUBERIA Ø 2" PVC SAP | 15d | 2023-04-14 | 2023-05-01 | 243SS | 8d | 0d | 323.75 | 03.03.05 |
| 245 | 1.4.3.6 | SUMINISTRO Y COLOCACION DE CODO 90° PVC SAP Ø 1/2" | 15d | 2023-04-14 | 2023-05-01 | 244SS | 8d | 0d | 751.52 | 03.03.06 |
| 246 | 1.4.3.7 | SUMINISTRO E INSTALACION DE CODO 90° PVC SAP Ø 3/4" | 15d | 2023-04-14 | 2023-05-01 | 245SS | 8d | 0d | 51.06 | 03.03.07 |
| 247 | 1.4.3.8 | SUMINISTRO Y COLOCACION DE CODO 90° PVC SAP Ø 1" | 15d | 2023-04-14 | 2023-05-01 | 246SS | 8d | 0d | 64.98 | 03.03.08 |
| 248 | 1.4.3.9 | SUMINISTRO Y COLOCACION DE CODO 90° PVC SAP Ø 2" | 15d | 2023-04-14 | 2023-05-01 | 247SS | 8d | 0d | 13.58 | 03.03.09 |
| 249 | 1.4.3.10 | SUMINISTRO Y COLOCACION DE REDUCCION PVC SAP Ø 3/4" A 1/2" | 15d | 2023-04-14 | 2023-05-01 | 248SS | 8d | 0d | 47.84 | 03.03.10 |
| 250 | 1.4.3.11 | SUMINISTRO Y COLOCACION DE REDUCCION PVC SAP Ø 1" A 3/4" | 15d | 2023-04-14 | 2023-05-01 | 249SS | 8d | 0d | 26.1 | 03.03.11 |
| 251 | 1.4.3.12 | SUMINISTRO Y COLOCACION DE REDUCCION PVC SAP Ø 1" A 1/2" | 15d | 2023-04-14 | 2023-05-01 | 250SS | 8d | 0d | 56.52 | 03.03.12 |
| 252 | 1.4.3.13 | SUMINISTRO Y COLOCACION DE REDUCCION PVC SAP Ø 2" A 1" | 15d | 2023-04-14 | 2023-05-01 | 251SS | 8d | 0d | 23.88 | 03.03.13 |
| 253 | 1.4.3.14 | SUMINISTRO E INSTALACIÓN DE TEE DE PVC SAP Ø 1/2" | 15d | 2023-04-14 | 2023-05-01 | 252SS | 8d | 0d | 175.6 | 03.03.14 |
| 254 | 1.4.3.15 | SUMINISTRO E INSTALACIÓN DE TEE DE PVC SAP Ø 3/4" | 15d | 2023-04-14 | 2023-05-01 | 253SS | 8d | 0d | 48.15 | 03.03.15 |
| 255 | 1.4.3.16 | SUMINISTRO E INSTALACIÓN DE TEE DE PVC SAP Ø 1" | 15d | 2023-04-14 | 2023-05-01 | 254SS | 8d | 0d | 75.74 | 03.03.16 |
| 256 | 1.4.3.17 | SUMINISTRO E INSTALACION DE VALVULA COMPUERTA DE Ø 1/2" | 15d | 2023-04-14 | 2023-05-01 | 255SS | 8d | 0d | 1,544.25 | 03.03.17 |
| 257 | 1.4.3.18 | SUMINISTRO E INSTALACION DE VALVULA COMPUERTA DE Ø 3/4" | 15d | 2023-04-14 | 2023-05-01 | 256SS | 8d | 0d | 120.82 | 03.03.18 |
| 258 | 1.4.3.19 | SUMINISTRO E INSTALACION DE VALVULA COMPUERTA DE BRONCE DE 2" | 15d | 2023-04-14 | 2023-05-01 | 257SS | 8d | 0d | 224.37 | 03.03.19 |
| 259 | 1.4.3.20 | SUMINISTRO E INSTALACION DE UNION UNIVERSAL DE PVC Ø 1/2" | 15d | 2023-04-14 | 2023-05-01 | 258SS | 8d | 0d | 174.36 | 03.03.20 |
| 260 | 1.4.3.21 | SUMINISTRO E INSTALACION DE UNION UNIVERSAL DE PVC Ø 3/4" | 15d | 2023-04-14 | 2023-05-01 | 259SS | 8d | 0d | 195.72 | 03.03.21 |
| 261 | 1.4.3.22 | SUMINISTRO E INSTALACION DE UNION UNIVERSAL DE PVC Ø 2" | 15d | 2023-04-14 | 2023-05-01 | 260SS | 8d | 0d | 424.8 | 03.03.22 |
| 262 | 1.4.3.23 | SUMINISTRO E INSTALACION DE ABRAZADERA DE 2" | 15d | 2023-04-14 | 2023-05-01 | 261SS | 8d | 0d | 48.9 | 03.03.23 |

| ID | WBS | Task | Duration | Start | Finish | Predecessors | Total slack | Free slack | Cost | Text1 |
| --- | --- | --- | --- | --- | --- | --- | --- | --- | --- | --- |
| 263 | 1.4.4 | **OPERATIVIDAD DE ALMACENAMIENTO DE AGUA EN CISTERNA Y TANQUE ELEVADO** | 10d | 2023-05-04 | 2023-05-15 |  | 8d |  | 2,394.45 | 03.04 |
| 264 | 1.4.4.1 | SUMINISTRO E INSTALACION DE TAPON CEBADO PVC Ø 1" | 10d | 2023-05-04 | 2023-05-15 | 294 | 8d | 0d | 10.88 | 03.04.01 |
| 265 | 1.4.4.2 | SUMINISTRO E INSTALACION DE UNIÓN UNIVERSAL DE PVC Ø 1" | 10d | 2023-05-04 | 2023-05-15 | 264SS | 8d | 0d | 65.92 | 03.04.02 |
| 266 | 1.4.4.3 | SUMINISTRO E INSTALACION DE UNIÓN UNIVERSAL DE PVC Ø 2" | 10d | 2023-05-04 | 2023-05-15 | 265SS | 8d | 0d | 103.48 | 03.04.03 |
| 267 | 1.4.4.4 | SUMINISTRO E INSTALACION DE VALVULA CHECK DE BRONCE Ø 1" | 10d | 2023-05-04 | 2023-05-15 | 266SS | 8d | 0d | 59.32 | 03.04.04 |
| 268 | 1.4.4.5 | SUMINISTRO E INSTALACIÓN DE VÁLVULA DE PIE C/CANASTILLA DE Ø 1" | 10d | 2023-05-04 | 2023-05-15 | 267SS | 8d | 0d | 62.54 | 03.04.05 |
| 269 | 1.4.4.6 | SUMINISTRO E INSTALACIÓN DE VÁLVULA COMPUERTA DE BRONCE Ø 3/4" INC/CAJA DE CONCRETO PARA AGUA | 10d | 2023-05-04 | 2023-05-15 | 268SS | 8d | 0d | 114.51 | 03.04.06 |
| 270 | 1.4.4.7 | SUMINISTRO E INSTALACIÓN DE VÁLVULA COMPUERTA DE BRONCE Ø 1" | 10d | 2023-05-04 | 2023-05-15 | 269SS | 8d | 0d | 84.64 | 03.04.07 |
| 271 | 1.4.4.8 | SUMINISTRO E INSTALACION DE VALVULA COMPUERTA DE BRONCE DE 2" INC/CAJA DE CONCRETO PARA AGUA | 10d | 2023-05-04 | 2023-05-15 | 270SS | 8d | 0d | 448.74 | 03.04.08 |
| 272 | 1.4.4.9 | SUMINISTRO E INSTALACION VALVULAS Y FLOTADOR 3/4 INC/BUSHING 1" A 3/4" | 10d | 2023-05-04 | 2023-05-15 | 271SS | 8d | 0d | 157.05 | 03.04.09 |
| 273 | 1.4.4.10 | INSTALACION Y PUESTA EN FUNCIONAMIENTO DE CISTERNA Y TANQUE ELEVADO | 10d | 2023-05-04 | 2023-05-15 | 272SS | 8d | 0d | 1,287.37 | 03.04.10 |
| 274 | 1.4.5 | **INSTALACIONES DE DESAGUE** | 12d | 2023-04-20 | 2023-05-03 |  | 8d |  | 12,122.68 | 03.05 |
| 275 | 1.4.5.1 | SALIDAS PARA VENTILACION DE Ø 2" | 12d | 2023-04-20 | 2023-05-03 | 262SS+5d | 8d | 0d | 768.48 | 03.05.01 |
| 276 | 1.4.5.2 | SALIDAS PARA TUBO DE PVC Ø 2" | 12d | 2023-04-20 | 2023-05-03 | 275SS | 8d | 0d | 1,681.05 | 03.05.02 |
| 277 | 1.4.5.3 | SALIDAS PARA TUBO DE PVC Ø 4" | 12d | 2023-04-20 | 2023-05-03 | 276SS | 8d | 0d | 1,602.18 | 03.05.03 |
| 278 | 1.4.5.4 | RED DE DISTRIBUCION PVC SAP PARA DESAGUE DE Ø 2" | 12d | 2023-04-20 | 2023-05-03 | 277SS | 8d | 0d | 830.25 | 03.05.04 |
| 279 | 1.4.5.5 | RED DE DISTRIBUCION PVC SAP PARA DESAGUE DE Ø 4" | 12d | 2023-04-20 | 2023-05-03 | 278SS | 8d | 0d | 1,727.53 | 03.05.05 |
| 280 | 1.4.5.6 | SUMINISTRO E INSTALACIÓN DE CODO 45° PVC SAP Ø 2" | 12d | 2023-04-20 | 2023-05-03 | 279SS | 8d | 0d | 140 | 03.05.06 |
| 281 | 1.4.5.7 | SUMINISTRO E INSTALACION DE CODO 45º PVC SAP Ø 4" | 12d | 2023-04-20 | 2023-05-03 | 280SS | 8d | 0d | 115.56 | 03.05.07 |
| 282 | 1.4.5.8 | SUMINISTRO E INSTALACIÓN DE YEE PVC SAP Ø 4" | 12d | 2023-04-20 | 2023-05-03 | 281SS | 8d | 0d | 183.56 | 03.05.08 |
| 283 | 1.4.5.9 | SUMINISTRO E INSTALACIÓN DE YEE PVC SAP Ø 2" | 12d | 2023-04-20 | 2023-05-03 | 282SS | 8d | 0d | 117.6 | 03.05.09 |
| 284 | 1.4.5.10 | SUMINISTRO E INSTALACIÓN DE YEE PVC SAP Ø 4" A 2" | 12d | 2023-04-20 | 2023-05-03 | 283SS | 8d | 0d | 305.34 | 03.05.10 |
| 285 | 1.4.5.11 | SUMINISTRO E INSTALACION DE TEE PVC SAP Ø 4" | 12d | 2023-04-20 | 2023-05-03 | 284SS | 8d | 0d | 295.56 | 03.05.11 |
| 286 | 1.4.5.12 | SUMINISTRO E INSTALACION DE TEE PVC SAP Ø 2" | 12d | 2023-04-20 | 2023-05-03 | 285SS | 8d | 0d | 131.1 | 03.05.12 |
| 287 | 1.4.5.13 | SUMINISTRO E INSTALACION DE CODO 90° PVC SAP Ø DE 4" | 12d | 2023-04-20 | 2023-05-03 | 286SS | 8d | 0d | 117.2 | 03.05.13 |
| 288 | 1.4.5.14 | SUMINISTRO E INSTALACION DE CODO 90° PVC SAP Ø DE 2" | 12d | 2023-04-20 | 2023-05-03 | 287SS | 8d | 0d | 100.98 | 03.05.14 |
| 289 | 1.4.5.15 | SUMINISTRO E INSTALACION DE TAPAS DE REGISTRO ROSCADO DE BRONCE DE Ø 4" | 12d | 2023-04-20 | 2023-05-03 | 288SS | 8d | 0d | 292.32 | 03.05.15 |
| 290 | 1.4.5.16 | SUMINISTRO E INSTALACION DE SUMIDERO CROMADO REJILLA DE BRONCE DE Ø 2" | 12d | 2023-04-20 | 2023-05-03 | 289SS | 8d | 0d | 380.94 | 03.05.16 |
| 291 | 1.4.5.17 | SUMINISTRO E INSTALACIÓN DE SOMBRERO VENTILACION PVC DE Ø 2" | 12d | 2023-04-20 | 2023-05-03 | 290SS | 8d | 0d | 178.68 | 03.05.17 |
| 292 | 1.4.5.18 | SUMINISTRO E INSTALACION DE TRAMPA "P" PARA SUMIDERO PVC DE Ø 2" | 12d | 2023-04-20 | 2023-05-03 | 291SS | 8d | 0d | 620.62 | 03.05.18 |
| 293 | 1.4.5.19 | SUMINISTRO E INSTALACION DE CAJA DE REGISTRO 30" x 60" INCLUYE MARCO Y TAPA | 12d | 2023-04-20 | 2023-05-03 | 292SS | 8d | 0d | 2,378.64 | 03.05.19 |
| 294 | 1.4.5.20 | SUMINISTRO E INSTALACION PVC SAP DE 4" A 2" | 12d | 2023-04-20 | 2023-05-03 | 293SS | 8d | 0d | 155.09 | 03.05.20 |

| ID | WBS | Task | Duration | Start | Finish | Predecessors | Total slack | Free slack | Cost | Text1 |
| --- | --- | --- | --- | --- | --- | --- | --- | --- | --- | --- |
| 295 | 1.4.6 | **APARATOS SANITARIOS Y ACCESORIOS** | 6d | 2023-06-15 | 2023-06-21 |  | 8d |  | 18,574.06 | 03.06 |
| 296 | 1.4.6.1 | SUMINISTRO E INSTALACION DE INODORO ONE PIECE DE LOSA COLOR BLANCO INCLUYE ACCESORIOS, PARA ADULTOS | 6d | 2023-06-15 | 2023-06-21 | 323 | 8d | 0d | 5,404.52 | 03.06.01 |
| 297 | 1.4.6.2 | SUMINISTRO E INSTALACION DE INODORO ONE PIECE DE LOSA COLOR BLANCO INCLUYE ACCESORIOS, PARA NIÑOS | 6d | 2023-06-15 | 2023-06-21 | 296SS | 8d | 0d | 1,473.96 | 03.06.02 |
| 298 | 1.4.6.3 | SUMINISTRO E INSTALACION DE OVALIN LOSA BLANCA CON ACCESORIOS | 6d | 2023-06-15 | 2023-06-21 | 297SS | 8d | 0d | 1,530.12 | 03.06.03 |
| 299 | 1.4.6.4 | SUMINISTRO E INSTALACION DE LAVATORIO BLANCO CON PEDESTAL Y ACCESORIOS, PARA NIÑO | 6d | 2023-06-15 | 2023-06-21 | 298SS | 8d | 0d | 631.05 | 03.06.04 |
| 300 | 1.4.6.5 | SUMINISTRO E INSTALACION DE LAVATORIO BLANCO CON PEDESTAL Y ACCESORIOS, PARA ADULTO | 6d | 2023-06-15 | 2023-06-21 | 299SS | 8d | 0d | 1,472.45 | 03.06.05 |
| 301 | 1.4.6.6 | SUMINISTRO E INSTALACION DE LAVADERO DE ACERO INOXIDABLE CON ESCURRIDERO | 6d | 2023-06-15 | 2023-06-21 | 300SS | 8d | 0d | 747.52 | 03.06.06 |
| 302 | 1.4.6.7 | SUMINISTRO E INSTALACION DE DISPENSADOR DE PAPEL HIGIENICO LOSA COLOR BLANCO | 6d | 2023-06-15 | 2023-06-21 | 301SS | 8d | 0d | 2,177.28 | 03.06.07 |
| 303 | 1.4.6.8 | SUMINISTRO E INSTALACIÓN DE LLAVE CROMADA DE 1/2" P/LAVATORIOS INCLUYE ACCESORIOS | 6d | 2023-06-15 | 2023-06-21 | 302SS | 8d | 0d | 3,753.92 | 03.06.08 |
| 304 | 1.4.6.9 | SUMINISTRO E INSTALACION DE LLAVE TIPO CUELLO GANSO CROMADA P/LAVADERO 1/2" | 6d | 2023-06-15 | 2023-06-21 | 303SS | 8d | 0d | 333.1 | 03.06.09 |
| 305 | 1.4.6.10 | SUMINISTRO E INSTALACION DE PAPELERA DE ACERO INOXIDABLE | 6d | 2023-06-15 | 2023-06-21 | 304SS | 8d |  | 1,050.14 | 03.06.10 |
| 306 | 1.4.7 | **OTROS** | 12d | 2023-05-04 | 2023-05-17 |  | 8d |  | 8,625.02 | 03.07 |
| 307 | 1.4.7.1 | PRUEBA HIDRAULICA Y DESINFECCION P/TUBERIA DE AGUA POTABLE | 12d | 2023-05-04 | 2023-05-17 | 273SS | 8d | 0d | 800.66 | 03.07.01 |
| 308 | 1.4.7.2 | PRUEBA HIDRAULICA DE REDES DE ALCANTARILLADO | 12d | 2023-05-04 | 2023-05-17 | 307SS | 8d | 0d | 1,841.74 | 03.07.02 |
| 309 | 1.4.7.3 | SUMINISTRO E INSTALACION DE TAPA METALICA DE 0.60x0.60m, PLANCHA e=3/16" | 12d | 2023-05-04 | 2023-05-17 | 308SS | 8d | 0d | 886.7 | 03.07.03 |
| 310 | 1.4.7.4 | SUMINISTRO E INSTALACION DE ESCALERA DE GATO GALVANIZADA PARA TANQUE ELEVADO | 12d | 2023-05-04 | 2023-05-17 | 309SS | 8d | 0d | 2,095.92 | 03.07.04 |
| 311 | 1.4.7.5 | TRANSPORTE DE MATERIALES A OBRA | 12d | 2023-05-04 | 2023-05-17 | 310SS | 8d | 0d | 3,000 | 03.07.05 |
| 312 | 1.4.8 | **DRENAJE PLUVIAL Y BIODIGESTOR** | 24d | 2023-05-18 | 2023-06-14 |  | 8d |  | 54,281.28 | 03.08 |
| 313 | 1.4.8.1 | **CUNETAS, CANALETAS Y BIODIGESTOR** | 24d | 2023-05-18 | 2023-06-14 |  | 8d |  | 54,281.28 | 03.08.01 |
| 314 | 1.4.8.1.1 | CUNETA DE EVACUAION PLUVIAL, CONCRETO F'C=175 KG/CM2 - CEMENTO TIPO MS | 3d | 2023-05-25 | 2023-05-27 | 315 | 8d | 0d | 4,788.07 | 03.08.01.01 |
| 315 | 1.4.8.1.2 | CUNETA DE EVACUAION PLUVIAL, ENCOFRADO Y DESENCOFRADO | 4d | 2023-05-20 | 2023-05-24 | 318 | 8d | 0d | 9,043.04 | 03.08.01.02 |
| 316 | 1.4.8.1.3 | TARRAJEO DE CUNETAS PROP. 1:4 - CEMENTO TIPO MS | 5d | 2023-05-27 | 2023-06-01 | 314SS+2d | 8d | 0d | 8,218.25 | 03.08.01.03 |
| 317 | 1.4.8.1.4 | SUMINISTRO Y COLOCACION DE REJILLA METALICA CON ANGULO DE 1 1/2" x 1 1/2" x 3/16" Y PLATINA 1" x 1" x 1/8" SEGUN DISEÑO | 5d | 2023-06-02 | 2023-06-07 | 316 | 8d | 0d | 13,076.44 | 03.08.01.04 |
| 318 | 1.4.8.1.5 | SOLADO PROP. 1:8 e=0.10m | 2d | 2023-05-18 | 2023-05-19 | 311 | 8d | 0d | 103.88 | 03.08.01.05 |
| 319 | 1.4.8.1.6 | SUMINISTRO E INSTALACION DE TANQUE BIODIGESTOR DE 1300 LITROS, INCL. ACCESORIOS Y ACOMETIDA PARA INGRESO DE AGUAS RESIDUALES | 6d | 2023-06-08 | 2023-06-14 | 317 | 8d | 0d | 9,139.4 | 03.08.01.06 |
| 320 | 1.4.8.1.7 | SUMINISTRO E INSTALACION DE CAJA RECOLECTORA DE LODO DE 0.85x0.85x0.90m INCL. TAPA | 6d | 2023-06-08 | 2023-06-14 | 319SS | 8d | 0d | 3,573.4 | 03.08.01.07 |
| 321 | 1.4.8.1.8 | SUMINISTRO E INSTALACION DE TAPA METALICA DE 0.70x0.70m, PLANCHA e=3/16" | 6d | 2023-06-08 | 2023-06-14 | 320SS | 8d | 0d | 1,648.08 | 03.08.01.08 |
| 322 | 1.4.8.1.9 | SUMINISTRO E INSTALACION DE POZO DE ABSORCION 1.20x1.20x2.00m | 6d | 2023-06-08 | 2023-06-14 | 321SS | 8d | 0d | 4,010.72 | 03.08.01.09 |
| 323 | 1.4.8.1.10 | SALIDA DE TUBERIA DE PVC DE Ø 6" A QUEBRADA EXISTENTE | 6d | 2023-06-08 | 2023-06-14 | 322SS | 8d | 0d | 680 | 03.08.01.10 |

| ID | WBS | Task | Duration | Start | Finish | Predecessors | Total slack | Free slack | Cost | Text1 |
| --- | --- | --- | --- | --- | --- | --- | --- | --- | --- | --- |
| 324 | 1.5 | **INSTALACIONES ELECTRICAS** | 50d | 2023-04-27 | 2023-06-23 |  | 6d |  | 210,641.27 | 04 |
| 325 | 1.5.1 | **DESCRIPCION DE EQUIPOS** | 50d | 2023-04-27 | 2023-06-23 |  | 6d |  | 210,641.27 | 04.01 |
| 326 | 1.5.1.1 | **SUMINISTRO E INSTALACION DE EQUIPOS** | 10d | 2023-04-27 | 2023-05-08 |  | 6d |  | 32,393.3 | 04.01.01 |
| 327 | 1.5.1.1.1 | PANEL LED CUADRADO DE 24w-DL252-4000 K | 10d | 2023-04-27 | 2023-05-08 | 42SS-10d | 6d | 0d | 12,777.19 | 04.01.01.01 |
| 328 | 1.5.1.1.2 | PANEL LED REDONDO DE 24w-DL252-4000 K | 10d | 2023-04-27 | 2023-05-08 | 327SS | 6d | 0d | 6,651.14 | 04.01.01.02 |
| 329 | 1.5.1.1.3 | PANEL LED REDONDO DE 15w-DL252-4000 K | 10d | 2023-04-27 | 2023-05-08 | 328SS | 6d | 0d | 3,875.32 | 04.01.01.03 |
| 330 | 1.5.1.1.4 | PROYECTOR LED DE 200w-220v-4000K-BVP382 | 10d | 2023-04-27 | 2023-05-08 | 329SS | 6d | 0d | 8,929.62 | 04.01.01.04 |
| 331 | 1.5.1.1.5 | TIMBRE TIPO CAMPANILLA 6" De diammetro v 220v | 10d | 2023-04-27 | 2023-05-08 | 330SS | 6d | 0d | 160.03 | 04.01.01.05 |
| 332 | 1.5.1.2 | **SUMINISTRO E INSTALACION DE ACCESORIOS PARA INSTALACIONES ELECTRICAS** | 12d | 2023-05-04 | 2023-05-17 |  | 6d |  | 4,987.95 | 04.01.02 |
| 333 | 1.5.1.2.1 | INTERRUPTOR SIMPLE | 12d | 2023-05-04 | 2023-05-17 | 331SS+6d | 6d | 0d | 959.76 | 04.01.02.01 |
| 334 | 1.5.1.2.2 | INTERRUPTOR DOBLE | 12d | 2023-05-04 | 2023-05-17 | 333SS | 6d | 0d | 489.97 | 04.01.02.02 |
| 335 | 1.5.1.2.3 | INTERRUPTOR DE 3 VIAS CONMUTACION SIMPLE | 12d | 2023-05-04 | 2023-05-17 | 334SS | 6d | 0d | 99.22 | 04.01.02.03 |
| 336 | 1.5.1.2.4 | TOMACORRIENTE DOBLE CON TOMA A TIERRA | 12d | 2023-05-04 | 2023-05-17 | 335SS | 6d | 0d | 3,439 | 04.01.02.04 |
| 337 | 1.5.1.3 | **SUMINISTRO E INSTALACION DE CONDUCTORES Y DUCTOS** | 15d | 2023-05-09 | 2023-05-25 |  | 6d |  | 18,626.95 | 04.01.03 |
| 338 | 1.5.1.3.1 | CONDUCTOR DE 2.5 mm2 NH-80 | 15d | 2023-05-09 | 2023-05-25 | 336FS-8d | 6d | 0d | 3,634.48 | 04.01.03.01 |
| 339 | 1.5.1.3.2 | CONDUCTOR DE 4 mm2 NH-80 | 15d | 2023-05-09 | 2023-05-25 | 338SS | 6d | 0d | 2,422.56 | 04.01.03.02 |
| 340 | 1.5.1.3.3 | CONDUCTOR DE 6 mm2 NH-80 | 15d | 2023-05-09 | 2023-05-25 | 339SS | 6d | 0d | 179.64 | 04.01.03.03 |
| 341 | 1.5.1.3.4 | CONDUCTOR DE 6 mm2 N2XOH | 15d | 2023-05-09 | 2023-05-25 | 340SS | 6d | 0d | 2,301.46 | 04.01.03.04 |
| 342 | 1.5.1.3.5 | CONDUCTOR DE 10 mm2 N2XOH | 15d | 2023-05-09 | 2023-05-25 | 341SS | 6d | 0d | 1,760.35 | 04.01.03.05 |
| 343 | 1.5.1.3.6 | CONDUCTOR DE 16 mm2 N2XOH | 15d | 2023-05-09 | 2023-05-25 | 342SS | 6d | 0d | 1,354.92 | 04.01.03.06 |
| 344 | 1.5.1.3.7 | CONDUCTOR DE NLT DE 1-3x14 AWG | 15d | 2023-05-09 | 2023-05-25 | 343SS | 6d | 0d | 150.21 | 04.01.03.07 |
| 345 | 1.5.1.3.8 | CONDUCTOR TIPO PT DE 6 mm2 (Amarillo/Verde) | 15d | 2023-05-09 | 2023-05-25 | 344SS | 6d | 0d | 94.32 | 04.01.03.08 |
| 346 | 1.5.1.3.9 | CONDUCTOR TIPO PT DE 10 mm2 (Amarillo/Verde) | 15d | 2023-05-09 | 2023-05-25 | 345SS | 6d | 0d | 787 | 04.01.03.09 |
| 347 | 1.5.1.3.10 | DUCTO DE 20mm PVC (Pesado) | 15d | 2023-05-09 | 2023-05-25 | 346SS | 6d | 0d | 2,124.36 | 04.01.03.10 |
| 348 | 1.5.1.3.11 | DUCTO DE 25mm PVC (Pesado) | 15d | 2023-05-09 | 2023-05-25 | 347SS | 6d | 0d | 52.8 | 04.01.03.11 |
| 349 | 1.5.1.3.12 | DUCTO DE 33mm PVC (Pesado) | 15d | 2023-05-09 | 2023-05-25 | 348SS | 6d | 0d | 1,729.44 | 04.01.03.12 |
| 350 | 1.5.1.3.13 | CANALETA DE 39*19 mm PVC | 15d | 2023-05-09 | 2023-05-25 | 349SS | 6d | 0d | 1,101.12 | 04.01.03.13 |
| 351 | 1.5.1.3.14 | CURVA DE 20mm PVC (Pesado) | 15d | 2023-05-09 | 2023-05-25 | 350SS | 6d | 0d | 653.25 | 04.01.03.14 |
| 352 | 1.5.1.3.15 | CURVA DE 25mm PVC (Pesado) | 15d | 2023-05-09 | 2023-05-25 | 351SS | 6d | 0d | 9.64 | 04.01.03.15 |
| 353 | 1.5.1.3.16 | CURVA DE 33mm PVC (Pesado) | 15d | 2023-05-09 | 2023-05-25 | 352SS | 6d | 0d | 67.15 | 04.01.03.16 |
| 354 | 1.5.1.3.17 | MANGUERA CORRUGADA DE 15mm PVC | 15d | 2023-05-09 | 2023-05-25 | 353SS | 6d | 0d | 204.25 | 04.01.03.17 |

| ID | WBS | Task | Duration | Start | Finish | Predecessors | Total slack | Free slack | Cost | Text1 |
| --- | --- | --- | --- | --- | --- | --- | --- | --- | --- | --- |
| 355 | 1.5.1.4 | **SUMINISTRO E INSTALACION DE CAJAS Y VARIOS** | 15d | 2023-05-09 | 2023-05-25 |  | 6d |  | 17,432.59 | 04.01.04 |
| 356 | 1.5.1.4.1 | CAJA RECTANGULAR DE 100x50x55 mm PVC (Pesada) | 15d | 2023-05-09 | 2023-05-25 | 354SS | 6d | 0d | 938.6 | 04.01.04.01 |
| 357 | 1.5.1.4.2 | CAJA OCTOGONAL DE 100x100x40 mm PVC (Pesada) | 15d | 2023-05-09 | 2023-05-25 | 356SS | 6d | 0d | 1,338.75 | 04.01.04.02 |
| 358 | 1.5.1.4.3 | CAJA MODULAR DE 100x50x55 mm DE PVC | 15d | 2023-05-09 | 2023-05-25 | 357SS | 6d | 0d | 782.5 | 04.01.04.03 |
| 359 | 1.5.1.4.4 | CAJA DE PASO DE 150x150x80mm F°G° | 15d | 2023-05-09 | 2023-05-25 | 358SS | 6d | 0d | 61.68 | 04.01.04.04 |
| 360 | 1.5.1.4.5 | CAJA DE PASO DE 120x120x80mm PVC | 15d | 2023-05-09 | 2023-05-25 | 359SS | 6d | 0d | 109 | 04.01.04.05 |
| 361 | 1.5.1.4.6 | CAJA DE PASO DE 300x300x100 mm F°G° | 15d | 2023-05-09 | 2023-05-25 | 360SS | 6d | 0d | 131.42 | 04.01.04.06 |
| 362 | 1.5.1.4.7 | CINTA AISLANTE 3mm/1600 | 15d | 2023-05-09 | 2023-05-25 | 361SS | 6d | 0d | 234 | 04.01.04.07 |
| 363 | 1.5.1.4.8 | CINTA VULCANIZANTE 3mm/1600 | 15d | 2023-05-09 | 2023-05-25 | 362SS | 6d | 0d | 161.2 | 04.01.04.08 |
| 364 | 1.5.1.4.9 | CINTA SEÑALIZADORA DE BAJA TENSION rollo x 100m | 15d | 2023-05-09 | 2023-05-25 | 363SS | 6d | 0d | 175.24 | 04.01.04.09 |
| 365 | 1.5.1.4.10 | BUZONES ELECTRICOS C.A.C | 15d | 2023-05-09 | 2023-05-25 | 364SS | 6d | 0d | 8,674.5 | 04.01.04.10 |
| 366 | 1.5.1.4.11 | ZANJEO, RELLENO Y AGREGADOS (0.60 x 0.40 mts) terreno natural | 15d | 2023-05-09 | 2023-05-25 | 365SS | 6d | 0d | 4,294.58 | 04.01.04.11 |
| 367 | 1.5.1.4.12 | PRECINTOS DE PRESION- sobre de 100 unidades y 30cm de longitud | 15d | 2023-05-09 | 2023-05-25 | 366SS | 6d | 0d | 179.91 | 04.01.04.12 |
| 368 | 1.5.1.4.13 | TUBO PEGAMENTO EPÓXICO DE ALTA PRESIÓN | 15d | 2023-05-09 | 2023-05-25 | 367SS | 6d | 0d | 174.7 | 04.01.04.13 |
| 369 | 1.5.1.4.14 | TUBO DE F°G° DE 1" De diametro y 5 mts de longitud | 15d | 2023-05-09 | 2023-05-25 | 368SS | 6d | 0d | 176.51 | 04.01.04.14 |
| 370 | 1.5.1.5 | **POZO A TIERRA** | 5d | 2023-05-24 | 2023-05-29 |  | 6d |  | 10,649.8 | 04.01.05 |
| 371 | 1.5.1.5.1 | INSTALACION Y CONSTRUCCION DE POZO A TIERRA CON PROTOCOLO DE PRUEBA | 5d | 2023-05-24 | 2023-05-29 | 369FS-2d | 6d | 0d | 10,649.8 | 04.01.05.01 |
| 372 | 1.5.1.6 | **SUMINISTRO E INSTALACION DE SENSORES DE HUMO** | 4d | 2023-05-30 | 2023-06-02 |  | 6d |  | 11,356.87 | 04.01.06 |
| 373 | 1.5.1.6.1 | INSTALACION Y CONFIGURACION DE CENTRAL DE ALARMA PARA SENSORES DE HUMO | 4d | 2023-05-30 | 2023-06-02 | 371 | 6d | 0d | 11,356.87 | 04.01.06.01 |
| 374 | 1.5.1.7 | **SUMINISTRO E INSTALACION DE DATA** | 6d | 2023-06-01 | 2023-06-07 |  | 6d |  | 2,200 | 04.01.07 |
| 375 | 1.5.1.7.1 | CENTRAL Y SALIDA DE DATA | 6d | 2023-06-01 | 2023-06-07 | 373SS+2d | 6d | 0d | 2,200 | 04.01.07.01 |
| 376 | 1.5.1.8 | **SUMINISTRO E INSTALACION DE BOMBA DE AGUA** | 3d | 2023-06-01 | 2023-06-03 |  | 6d |  | 2,016.71 | 04.01.08 |
| 377 | 1.5.1.8.1 | INSTALACION BOMBA DE AGUA 1hp_220v- 350 rpm - uso domestico - centrifuga | 3d | 2023-06-01 | 2023-06-03 | 375SS | 6d | 0d | 2,016.71 | 04.01.08.01 |
| 378 | 1.5.1.9 | **SUMINISTRO E INSTALACION DE TABLEROS Y SUB TABLEROS** | 20d | 2023-06-01 | 2023-06-23 |  | 6d |  | 10,843.01 | 04.01.09 |
| 379 | 1.5.1.9.1 | TABLERO GENERAL 220v-1f-2h-20kva/emprotrar. (ver unifi.) | 20d | 2023-06-01 | 2023-06-23 | 377SS | 6d | 0d | 1,116.21 | 04.01.09.01 |
| 380 | 1.5.1.9.2 | TABLERO (TD-01) 220V-1F-2hilos/18 polos/empotrar. riel din. | 20d | 2023-06-01 | 2023-06-23 | 379SS | 6d | 0d | 894.05 | 04.01.09.02 |
| 381 | 1.5.1.9.3 | TABLERO (TD-02) 220V-1F-2hilos/18 polos/empotrar. riel din. | 20d | 2023-06-01 | 2023-06-23 | 380SS | 6d | 0d | 932.05 | 04.01.09.03 |
| 382 | 1.5.1.9.4 | TABLERO (TD-03) 220V-1F-2hilos/18 polos/empotrar. riel din. | 20d | 2023-06-01 | 2023-06-23 | 381SS | 6d | 0d | 1,058.05 | 04.01.09.04 |
| 383 | 1.5.1.9.5 | TABLERO (TD-04) 220V-1F-2hilos/28 polos/empotrar. riel din. | 20d | 2023-06-01 | 2023-06-23 | 382SS | 6d | 0d | 1,511.86 | 04.01.09.05 |
| 384 | 1.5.1.9.6 | TABLERO (STD-01) 220v-1F-2HILOS-14 POLOS-EMPOTRAR (RIEL DIN) | 20d | 2023-06-01 | 2023-06-23 | 383SS | 6d | 0d | 704.96 | 04.01.09.06 |
| 385 | 1.5.1.9.7 | TABLERO (STD-02) 220v-1F-2HILOS-14 POLOS-EMPOTRAR (RIEL DIN) | 20d | 2023-06-01 | 2023-06-23 | 384SS | 6d | 0d | 742.96 | 04.01.09.07 |
| 386 | 1.5.1.9.8 | TABLERO (STD-03) 220v-1F-2HILOS-14 POLOS-EMPOTRAR (RIEL DIN) | 20d | 2023-06-01 | 2023-06-23 | 385SS | 6d | 0d | 704.96 | 04.01.09.08 |
| 387 | 1.5.1.9.9 | TABLERO (STD-04) 220v-1F-2HILOS-14 POLOS-EMPOTRAR (RIEL DIN) | 20d | 2023-06-01 | 2023-06-23 | 386SS | 6d | 0d | 704.96 | 04.01.09.09 |
| 388 | 1.5.1.9.10 | TABLERO (STD-05) 220v-1F-2HILOS-18 POLOS-EMPOTRAR (RIEL DIN) | 20d | 2023-06-01 | 2023-06-23 | 387SS | 6d | 0d | 826.35 | 04.01.09.10 |
| 389 | 1.5.1.9.11 | TABLERO (STD-A) 220v-1F-2HILOS-18 POLOS-EMPOTRAR (RIEL DIN) | 20d | 2023-06-01 | 2023-06-23 | 388SS | 6d | 0d | 1,392.43 | 04.01.09.11 |
| 390 | 1.5.1.9.12 | TABLERO (STD-B) 220v-1F-2HILOS-8 POLOS-EMPOTRAR (RIEL DIN) | 20d | 2023-06-01 | 2023-06-23 | 389SS | 6d | 0d | 254.17 | 04.01.09.12 |

| ID | WBS | Task | Duration | Start | Finish | Predecessors | Total slack | Free slack | Cost | Text1 |
| --- | --- | --- | --- | --- | --- | --- | --- | --- | --- | --- |
| 391 | 1.5.1.10 | **SUMINISTRO E INSTALACIÓN DE SISTEMA FOTOVOLTAICO 5KWP** | 20d | 2023-06-01 | 2023-06-23 |  | 6d |  | 39,785.89 | 04.01.10 |
| 392 | 1.5.1.10.1 | SISTEMA FOTOVOLTAICO EN RED DE 5KWP-MONOFASICO 220v | 20d | 2023-06-01 | 2023-06-23 | 390SS | 6d | 0d | 39,785.89 | 04.01.10.01 |
| 393 | 1.5.1.11 | **SUMINISTRO E INSTALACIÓN DE SISTEMA LUMINARIA INTEGRAL DE 100W** | 20d | 2023-06-01 | 2023-06-23 |  | 6d |  | 60,348.2 | 04.01.11 |
| 394 | 1.5.1.11.1 | SISTEMA DE LUMINARIA INTEGRADA DE 100w-12vdc-6h | 20d | 2023-06-01 | 2023-06-23 | 392SS | 6d | 0d | 60,348.2 | 04.01.11.01 |
| 395 | 1.6 | **MOBILIARIO Y EQUIPAMIENTO** | 25d | 2023-05-26 | 2023-06-23 |  | 6d |  | 218,675.71 | 05 |
| 396 | 1.6.1 | **MOBILIARIO** | 25d | 2023-05-26 | 2023-06-23 |  | 6d |  | 100,763.71 | 05.01 |
| 397 | 1.6.1.1 | SILLA METAL POLIPROPILENO INICIAL | 25d | 2023-05-26 | 2023-06-23 | 394SS-5d | 6d | 0d | 1,875 | 05.01.01 |
| 398 | 1.6.1.2 | SILLA METAL POLIPROPILENO PAR 1°A 2° PRIMARIA | 25d | 2023-05-26 | 2023-06-23 | 397SS | 6d | 0d | 1,450 | 05.01.02 |
| 399 | 1.6.1.3 | SILLA METAL POLIPROPILENO PAR 3°A 6° PRIMARIA | 25d | 2023-05-26 | 2023-06-23 | 398SS | 6d | 0d | 2,900 | 05.01.03 |
| 400 | 1.6.1.4 | SILLA METAL POLIPROPILENO PAR 1°A 2° SECUNDARIA | 25d | 2023-05-26 | 2023-06-23 | 399SS | 6d | 0d | 1,920 | 05.01.04 |
| 401 | 1.6.1.5 | SILLA METAL POLIPROPILENO PAR 3°A 5° SECUNDARIA | 25d | 2023-05-26 | 2023-06-23 | 400SS | 6d | 0d | 7,200 | 05.01.05 |
| 402 | 1.6.1.6 | SILLA METAL POLIPROPILENO PARA DOCENTE | 25d | 2023-05-26 | 2023-06-23 | 401SS | 6d | 0d | 1,700 | 05.01.06 |
| 403 | 1.6.1.7 | SILLA GIRATORIA | 25d | 2023-05-26 | 2023-06-23 | 402SS | 6d | 0d | 1,023.72 | 05.01.07 |
| 404 | 1.6.1.8 | SILLA APILABLE | 25d | 2023-05-26 | 2023-06-23 | 403SS | 6d | 0d | 3,075 | 05.01.08 |
| 405 | 1.6.1.9 | MESA METAL PROLIPROPILENO INICIAL | 25d | 2023-05-26 | 2023-06-23 | 404SS | 6d | 0d | 2,432.43 | 05.01.09 |
| 406 | 1.6.1.10 | MESA METAL POLIPROPILENO PARA 1° A 2° PRIMARIA | 25d | 2023-05-26 | 2023-06-23 | 405SS | 6d | 0d | 3,455.7 | 05.01.10 |
| 407 | 1.6.1.11 | MESA METAL POLIPROPILENO PARA 3° A 6° PRIMARIA | 25d | 2023-05-26 | 2023-06-23 | 406SS | 6d | 0d | 3,539.5 | 05.01.11 |
| 408 | 1.6.1.12 | MESA METAL POLIPROPILENO PARA 1° A 2° SECUNDARIA | 25d | 2023-05-26 | 2023-06-23 | 407SS | 6d | 0d | 4,348.08 | 05.01.12 |
| 409 | 1.6.1.13 | MESA METAL POLIPROPILENO PARA 3° A 5° SECUNDARIA | 25d | 2023-05-26 | 2023-06-23 | 408SS | 6d | 0d | 7,454.8 | 05.01.13 |
| 410 | 1.6.1.14 | MESA METAL POLIPROPILENO PARA DOCENTE | 25d | 2023-05-26 | 2023-06-23 | 409SS | 6d | 0d | 5,566 | 05.01.14 |
| 411 | 1.6.1.15 | MESA PARA LAPTOP PRIMARIA | 25d | 2023-05-26 | 2023-06-23 | 410SS | 6d | 0d | 410.3 | 05.01.15 |
| 412 | 1.6.1.16 | MESA PARA LAPTOP SECUNDARIA | 25d | 2023-05-26 | 2023-06-23 | 411SS | 6d | 0d | 6,352.5 | 05.01.16 |
| 413 | 1.6.1.17 | MESA METAL POLIPROPILENO BIBLIOTECA PRIMARIA | 25d | 2023-05-26 | 2023-06-23 | 412SS | 6d | 0d | 1,020.1 | 05.01.17 |
| 414 | 1.6.1.18 | MESA METAL POLIPROPILENO BIBLIOTECA SECUNDARIA | 25d | 2023-05-26 | 2023-06-23 | 413SS | 6d | 0d | 1,020.1 | 05.01.18 |
| 415 | 1.6.1.19 | MESA PLEGABLE | 25d | 2023-05-26 | 2023-06-23 | 414SS | 6d | 0d | 825 | 05.01.19 |
| 416 | 1.6.1.20 | ARMARIO DE MELAMINE DE DOS CUERPOS | 25d | 2023-05-26 | 2023-06-23 | 415SS | 6d | 0d | 1,398.62 | 05.01.20 |
| 417 | 1.6.1.21 | ARMARIO DE DOS PUERTAS (H:1.05) INICIAL | 25d | 2023-05-26 | 2023-06-23 | 416SS | 6d | 0d | 875.49 | 05.01.21 |
| 418 | 1.6.1.22 | ARMARIO DE METAL | 25d | 2023-05-26 | 2023-06-23 | 417SS | 6d | 0d | 16,783.44 | 05.01.22 |
| 419 | 1.6.1.23 | EXHIBIDOR DE LIBROS NIVEL INICIAL | 25d | 2023-05-26 | 2023-06-23 | 418SS | 6d | 0d | 1,097.56 | 05.01.23 |
| 420 | 1.6.1.24 | EXHIBIDOR MOVIL - NIVEL INICIAL | 25d | 2023-05-26 | 2023-06-23 | 419SS | 6d | 0d | 690.68 | 05.01.24 |
| 421 | 1.6.1.25 | ESTANTE PARA UTILES ESCOLARES (09 DIVISIONES) INICIAL | 25d | 2023-05-26 | 2023-06-23 | 420SS | 6d | 0d | 4,283.15 | 05.01.25 |
| 422 | 1.6.1.26 | ESTANTE PARA LIBROS | 25d | 2023-05-26 | 2023-06-23 | 421SS | 6d | 0d | 8,003.52 | 05.01.26 |
| 423 | 1.6.1.27 | ESTANTE DE ANGULO RANURADO | 25d | 2023-05-26 | 2023-06-23 | 422SS | 6d | 0d | 2,475 | 05.01.27 |
| 424 | 1.6.1.28 | CASILLEROS INDIVIDUALES (09) (NIVEL INICIAL) | 25d | 2023-05-26 | 2023-06-23 | 423SS | 6d | 0d | 2,072.04 | 05.01.28 |
| 425 | 1.6.1.29 | ARCHIVADOR METAL DE 04 GAVETAS | 25d | 2023-05-26 | 2023-06-23 | 424SS | 6d | 0d | 1,907.7 | 05.01.29 |
| 426 | 1.6.1.30 | CREDENZA | 25d | 2023-05-26 | 2023-06-23 | 425SS | 6d | 0d | 1,367.85 | 05.01.30 |
| 427 | 1.6.1.31 | ESCRITORIO ADMINISTRATIVO | 25d | 2023-05-26 | 2023-06-23 | 426SS | 6d | 0d | 850.45 | 05.01.31 |
| 428 | 1.6.1.32 | ESCRITORIO CON MESA DE REUNIONES PARA DIRECCION | 25d | 2023-05-26 | 2023-06-23 | 427SS | 6d | 0d | 1,389.98 | 05.01.32 |

| ID | WBS | Task | Type | Duration | Start | Finish | Predecessors | Total slack | Free slack | Cost | Text1 |
| --- | --- | --- | --- | --- | --- | --- | --- | --- | --- | --- | --- |
| 429 | 1.6.2 | **EQUIPAMIENTO** |  | 25d | 2023-05-26 | 2023-06-23 |  | 6d |  | 115,912 | 05.02 |
| 430 | 1.6.2.1 | COMPUTADORA PC |  | 25d | 2023-05-26 | 2023-06-23 | 428SS | 6d | 0d | 16,800 | 05.02.01 |
| 431 | 1.6.2.2 | COMPUTADORA PORTATIL - LAPTOP |  | 25d | 2023-05-26 | 2023-06-23 | 430SS | 6d | 0d | 70,200 | 05.02.02 |
| 432 | 1.6.2.3 | IMPRESORA MULTIFUNCIONAL |  | 25d | 2023-05-26 | 2023-06-23 | 431SS | 6d | 0d | 4,500 | 05.02.03 |
| 433 | 1.6.2.4 | PROYECTOR MULTIMEDIA |  | 25d | 2023-05-26 | 2023-06-23 | 432SS | 6d | 0d | 8,700 | 05.02.04 |
| 434 | 1.6.2.5 | PARLANTES MULTIMEDIA PARA LAPTOP |  | 25d | 2023-05-26 | 2023-06-23 | 433SS | 6d | 0d | 520 | 05.02.05 |
| 435 | 1.6.2.6 | PARLANTES |  | 25d | 2023-05-26 | 2023-06-23 | 434SS | 6d | 0d | 2,200 | 05.02.06 |
| 436 | 1.6.2.7 | ECRAN |  | 25d | 2023-05-26 | 2023-06-23 | 435SS | 6d | 0d | 1,650 | 05.02.07 |
| 437 | 1.6.2.8 | TELEVISOR |  | 25d | 2023-05-26 | 2023-06-23 | 436SS | 6d | 0d | 3,025 | 05.02.08 |
| 438 | 1.6.2.9 | EQUIPO BLURAY |  | 25d | 2023-05-26 | 2023-06-23 | 437SS | 6d | 0d | 825 | 05.02.09 |
| 439 | 1.6.2.10 | EQUIPO DE SONIDO |  | 25d | 2023-05-26 | 2023-06-23 | 438SS | 6d | 0d | 2,200 | 05.02.10 |
| 440 | 1.6.2.11 | REFRIGERADORA |  | 25d | 2023-05-26 | 2023-06-23 | 439SS | 6d | 0d | 1,549 | 05.02.11 |
| 441 | 1.6.2.12 | MICROONDAS |  | 25d | 2023-05-26 | 2023-06-23 | 440SS | 6d | 0d | 469 | 05.02.12 |
| 442 | 1.6.2.13 | COCINA |  | 25d | 2023-05-26 | 2023-06-23 | 441SS | 6d | 0d | 1,899 | 05.02.13 |
| 443 | 1.6.2.14 | RACK PARA PROYECTOR MULTIMEDIA |  | 25d | 2023-05-26 | 2023-06-23 | 442SS | 6d | 0d | 825 | 05.02.14 |
| 444 | 1.6.2.15 | RACK PARA DVD |  | 25d | 2023-05-26 | 2023-06-23 | 443SS | 6d | 0d | 275 | 05.02.15 |
| 445 | 1.6.2.16 | RACK PARA LA TV |  | 25d | 2023-05-26 | 2023-06-23 | 444SS | 6d | 0d | 275 | 05.02.16 |
| 446 | 1.6.3 | **FLETE TERRESTRE** |  | 25d | 2023-05-26 | 2023-06-23 |  | 6d |  | 2,000 | 05.03 |
| 447 | 1.6.3.1 | FLETE TERRESTRE |  | 25d | 2023-05-26 | 2023-06-23 | 445SS | 6d |  | 2,000 | 05.03.01 |
| 448 | 1.7 | **PLAN DE CONTINGENCIA** |  | 15d | 2023-01-02 | 2023-01-18 |  | 140d |  | 34,721.09 | 06 |
| 449 | 1.7.1 | DESMONTAJE DE CORREAS DE MADERA |  | 15d | 2023-01-02 | 2023-01-18 | 2SS | 140d | 0d | 268.83 | 06.01 |
| 450 | 1.7.2 | DESMONTAJE DE TIJERAL DE MADERA |  | 15d | 2023-01-02 | 2023-01-18 | 449SS | 140d | 0d | 59.74 | 06.02 |
| 451 | 1.7.3 | MUROS CON PLANCHA DE FIBROCEMENTO DE 6mm |  | 15d | 2023-01-02 | 2023-01-18 | 450SS | 140d | 0d | 13,781.55 | 06.03 |
| 452 | 1.7.4 | SUMINISTRO Y COLOCACION PUERTA DE MADERA CEDRO MACHIEMBRADA (1.00x2.10) |  | 15d | 2023-01-02 | 2023-01-18 | 451SS | 140d | 0d | 1,050.01 | 06.04 |
| 453 | 1.7.5 | SUMINISTRO Y COLOCACION DE VENTANA DE ALUMINIO Y VIDRIO DE 6mm CON LAMINA DE SEGURIDAD |  | 15d | 2023-01-02 | 2023-01-18 | 452SS | 140d | 0d | 1,627.92 | 06.05 |
| 454 | 1.7.6 | PINTURA LATEX EN MUROS EXTERIORES |  | 15d | 2023-01-02 | 2023-01-18 | 453SS | 140d | 0d | 2,774.42 | 06.06 |
| 455 | 1.7.7 | PINTURA LATEX EN MUROS INTERIORES |  | 15d | 2023-01-02 | 2023-01-18 | 454SS | 140d | 0d | 6,969.5 | 06.07 |
| 456 | 1.7.8 | SUMINISTRO Y COLOCACION DE COBERTURA LIVIANA DE FIBRA VEGETAL |  | 15d | 2023-01-02 | 2023-01-18 | 455SS | 140d | 0d | 3,104.89 | 06.08 |
| 457 | 1.7.9 | SUMINISTRO Y COLOCACION DE CUMBRERA DE FIBRA VEGETAL |  | 15d | 2023-01-02 | 2023-01-18 | 456SS | 140d | 0d | 306.13 | 06.09 |
| 458 | 1.7.10 | SUMINISTRO Y COLOCACION DE CORREA DE MADERA DE 4" X 2" |  | 15d | 2023-01-02 | 2023-01-18 | 457SS | 140d | 0d | 1,749.49 | 06.10 |
| 459 | 1.7.11 | MANTENIMIENTO DE SS.HH. |  | 15d | 2023-01-02 | 2023-01-18 | 458SS | 140d | 0d | 510.9 | 06.11 |
| 460 | 1.7.12 | LIMPIEZA Y DESINFECCION DE PISOS Y MUROS |  | 15d | 2023-01-02 | 2023-01-18 | 459SS | 140d | 0d | 1,661.92 | 06.12 |
| 461 | 1.7.13 | DESMONTAJE DE MUROS CON PLANCHA DE FIBROCEMENTO DE 6mm |  | 15d | 2023-01-02 | 2023-01-18 | 460SS | 140d |  | 855.79 | 06.13 |
| 462 | 1.8 | INICIO DEL PROYECTO | milestone | 0d | 2023-06-30 | 2023-06-30 | 120, 305, 447 | 0d |  |  |  |
